# CSF Upgrades and Migrations

How a schedule from MS Project changed from version to version. A marks actual dates.

## Version 1 (saved 2013-02-20)

| ID | WBS | Task | Duration | Start | Finish | Predecessors | Complete | Total float | Constraint |
| --- | --- | --- | --- | --- | --- | --- | --- | --- | --- |
| 1 |  | Upgrade CSF to 2.0 | 10d | 2013-01-14 A | 2013-01-25 A |  | 100% |  |  |
| 2 | 2 | **Upgrade of Existing CSF Apps to CSF 2.0** | 40d? | 2013-01-14 A | 2013-03-08 |  | 11% | 56d |  |
| 3 | 2.1 | **Development** | 18d | 2013-02-13 A | 2013-03-08 |  | 20% | 56d |  |
| 4 |  | Upgrade IAP | 4d | 2013-02-14 | 2013-02-20 | 1FS+13d |  | 60d |  |
| 5 |  | Upgrade Subject Evaluation | 4d | 2013-02-26 | 2013-03-01 | 4FS+3d |  | 60d |  |
| 6 |  | Upgrade Sponsor Billing | 4d | 2013-02-13 A | 2013-02-19 A | 1FS+12d | 100% |  |  |
| 7 |  | Upgrade Survey Engine | 4d | 2013-02-26 | 2013-03-01 | 6FS+4d |  | 55d |  |
| 8 |  | Upgrade Subject Evaluation Report | 4d | 2013-03-05 | 2013-03-08 | 7FS+1d |  | 55d |  |
| 9 |  | Upgrades complete | 0d | 2013-03-08 | 2013-03-08 | 4, 5, 6, 7, 8 |  | 56d |  |
| 10 | 2.2 | **Testing** | 34d? | 2013-01-14 | 2013-02-28 |  |  | 62d |  |
| 11 | 2.2.1 | **Test Planning** | 4d? | 2013-02-20 | 2013-02-25 |  |  | 62d |  |
| 12 |  | IAP and Sponsor Billing | 3d | 2013-02-20 | 2013-02-22 | 4SS+4d |  | 62d |  |
| 13 |  | OFS Applications | 1d? | 2013-02-25 | 2013-02-25 | 12 |  | 63d |  |
| 14 |  | Test Planning Complete | 0d | 2013-02-25 | 2013-02-25 | 12, 13 |  | 64d |  |
| 15 | 2.2.2 | **BA Testing** | 3d? | 2013-02-25 | 2013-02-27 |  |  | 62d |  |
| 16 |  | IAP and Sponsor Billing | 3d | 2013-02-25 | 2013-02-27 | 12 |  | 62d |  |
| 17 |  | OFS Applications | 1d? | 2013-02-26 | 2013-02-26 | 13 |  | 63d |  |
| 18 |  | BA Testing Complete | 0d | 2013-02-27 | 2013-02-27 | 16, 17 |  | 62d |  |
| 19 | 2.2.3 | **UAT** | 1d? | 2013-01-14 | 2013-01-14 |  |  | 94d |  |
| 20 |  | IAP | 1d? | 2013-01-14 | 2013-01-14 |  |  | 94d |  |
| 21 |  | Subject Evaluation | 1d? | 2013-01-14 | 2013-01-14 |  |  | 94d |  |
| 22 |  | Sponsor Billing | 1d? | 2013-01-14 | 2013-01-14 |  |  | 94d |  |
| 23 |  | Survey Engine | 1d? | 2013-01-14 | 2013-01-14 |  |  | 94d |  |
| 24 |  | Subject Evaluation Report | 1d? | 2013-01-14 | 2013-01-14 |  |  | 94d |  |
| 25 |  | UAT Complete | 0d | 2013-01-14 | 2013-01-14 | 20, 21, 22, 23, 24 |  | 94d |  |
| 26 |  | Testing Efforts Complete | 1d? | 2013-02-28 | 2013-02-28 | 14, 18, 25 |  | 62d |  |
| 27 | 2.3 | **Deployment Preparation** | 1d? | 2013-01-14 | 2013-01-14 |  |  | 94d |  |
| 28 |  | Create deployment plan | 1d? | 2013-01-14 | 2013-01-14 |  |  | 94d |  |
| 29 |  | Review deployment plan with participants | 1d? | 2013-01-14 | 2013-01-14 |  |  | 94d |  |
| 30 |  | Create registration support plan | 1d? | 2013-01-14 | 2013-01-14 |  |  | 94d |  |
| 31 | 2.4 | **Go-live** | 1d? | 2013-01-14 | 2013-01-14 |  |  | 95d |  |
| 32 |  | Prod smoke test | 1d? | 2013-01-14 | 2013-01-14 |  |  | 95d |  |
| 33 |  | Upgrade of Existing CSF Apps to CSF 2.0 Complete | 0d | 2013-01-14 | 2013-01-14 | 32 |  | 95d |  |
| 34 | 3 | **Convert SAIS-Common Apps to CSF 2.0** | 1d? | 2013-01-14 | 2013-01-14 |  |  | 95d |  |
| 35 |  | Development | 1d? | 2013-01-14 | 2013-01-14 |  |  | 95d |  |
| 36 |  | Testing | 1d? | 2013-01-14 | 2013-01-14 |  |  | 95d |  |
| 37 | 4 | **PE REG Upgrade** | 44d? | 2013-01-14 A | 2013-03-14 |  | 17% | 52d |  |
| 38 | 4.1 | **Phase I - Java 6, Touchstone, and CSF Enabling** | 26d? | 2013-02-07 A | 2013-03-14 |  | 20% | 52d |  |
| 39 | 4.1.1 | **Development** | 21d | 2013-02-07 A | 2013-03-07 |  | 25% | 52d |  |
| 40 |  | Do set-up and configuration required for upgrade | 5d | 2013-02-07 A | 2013-02-13 A |  | 100% |  |  |
| 41 |  | Perform upgrade | 5d | 2013-02-14 | 2013-02-21 | 40 |  | 52d |  |
| 42 |  | Unit test changes | 10d | 2013-02-22 | 2013-03-07 | 41 |  | 52d |  |
| 43 | 4.1.2 | **Testing** | 4d? | 2013-03-08 | 2013-03-13 |  |  | 52d |  |
| 44 |  | Test planning | 1d? | 2013-03-08 | 2013-03-08 | 42 |  | 52d |  |
| 45 |  | QA testing | 1d? | 2013-03-11 | 2013-03-11 | 44 |  | 52d |  |
| 46 |  | Load testing | 1d? | 2013-03-12 | 2013-03-12 | 45 |  | 52d |  |
| 47 |  | User | 1d? | 2013-03-13 | 2013-03-13 | 46 |  | 52d |  |
| 48 |  | Go-live | 1d? | 2013-03-14 | 2013-03-14 | 47 |  | 52d |  |
| 49 | 4.2 | **Phase II - Full CSF Upgrade** | 41d? | 2013-01-14 | 2013-03-11 |  |  | 55d |  |
| 50 | 4.2.1 | **Development** | 2d? | 2013-03-08 | 2013-03-11 |  |  | 54d |  |
| 51 |  | Perform full upgrade | 1d? | 2013-03-08 | 2013-03-08 | 42 |  | 54d |  |
| 52 |  | Unit test changes | 1d? | 2013-03-11 | 2013-03-11 | 51 |  | 54d |  |
| 53 | 4.2.2 | **Testing** | 1d? | 2013-01-14 | 2013-01-14 |  |  | 95d |  |
| 54 |  | QA | 1d? | 2013-01-14 | 2013-01-14 |  |  | 95d |  |
| 55 |  | User | 1d? | 2013-01-14 | 2013-01-14 |  |  | 95d |  |
| 56 |  | Go-live | 1d? | 2013-01-14 | 2013-01-14 |  |  | 95d |  |
| 57 |  | PE REG upgrade complete | 0d | 2013-03-14 | 2013-03-14 | 48, 56 |  | 52d |  |
| 58 | 5 | **Convert OREG to CSF 2.0** | 76d | 2013-02-11 | 2013-05-28 |  |  | 0d |  |
| 59 | 5.1 | **Development (including unit testing)** | 35d | 2013-02-11 | 2013-03-29 |  |  | 0d |  |
| 60 |  | Phase 1 - Required as-is , high priority (A/D and OREG) | 9d | 2013-02-11 | 2013-02-22 |  |  | 0d | start no earlier than 2013-02-11 |
| 61 |  | Phase 2 - Medium priority validation and messaging | 15d | 2013-02-25 | 2013-03-15 | 60 |  | 0d |  |
| 62 |  | Phase 3 - Stabilize JAR and rafactor CSF dependencies | 5d | 2013-03-18 | 2013-03-22 | 61 |  | 0d |  |
| 63 |  | Phase 4 - Modify OREG to use new JAR and upgrade to CSF 2.0 | 5d | 2013-03-25 | 2013-03-29 | 62 |  | 0d |  |
| 64 |  | Development complete | 0d | 2013-03-29 | 2013-03-29 | 63 |  | 0d |  |
| 65 |  | Regression Testing | 24d | 2013-04-01 | 2013-05-03 | 64 |  | 0d |  |
| 66 |  | UAT | 20d | 2013-04-29 | 2013-05-24 | 65FS-5d |  | 0d |  |
| 67 |  | Go-live | 0d | 2013-05-28 | 2013-05-28 |  |  | 0d | start no earlier than 2013-05-28 |
| 68 | 6 | **Notes Utility Beta** | 96d? | 2013-01-14 | 2013-05-28 |  |  | 0d |  |
| 69 |  | Development | 1d? | 2013-04-01 | 2013-04-01 | 59 |  | 39d |  |
| 70 |  | UAT | 1d? | 2013-01-14 | 2013-01-14 |  |  | 95d |  |

| ID | WBS | Task | Duration | Start | Finish | Total float | Constraint |
| --- | --- | --- | --- | --- | --- | --- | --- |
| 71 |  | Go-live | 0d | 2013-05-28 | 2013-05-28 | 0d | start no earlier than 2013-05-28 |
| 72 |  | Requirements | 1d? | 2013-01-14 | 2013-01-14 | 95d |  |
| 73 |  | Functional Specification | 1d? | 2013-01-14 | 2013-01-14 | 95d |  |
| 74 | 6.6 | **Technical Analysis and Design - Spring Messages** | 3d | 2013-01-14 | 2013-01-16 | 93d |  |
| 75 |  | Write Technical Specification | 3d | 2013-01-14 | 2013-01-16 | 93d |  |
| 76 |  | Review Technical Specification with Technical Team | 0d | 2013-01-14 | 2013-01-14 | 96d |  |
| 77 |  | Update Specification based on feedback | 2d | 2013-01-14 | 2013-01-15 | 94d |  |
| 78 |  | Technical Analysis and Design Complete | 0d | 2013-01-14 | 2013-01-14 | 96d |  |
| 79 | 6.7 | **Technical Analysis and Design - Rules Engine/OREG Decoupling** | 10d | 2013-01-14 | 2013-01-25 | 86d |  |
| 80 |  | Write Technical Specification | 10d | 2013-01-14 | 2013-01-25 | 86d |  |
| 81 | 6.8 | **Development** | 11d | 2013-01-14 | 2013-01-28 | 85d |  |
| 82 | 6.8.1 | **OREG** | 11d | 2013-01-14 | 2013-01-28 | 85d |  |
| 83 |  | Rules Engine/OREG Decoupling and integration testing | 5d | 2013-01-14 | 2013-01-18 | 91d |  |
| 84 |  | Common Changes (Desktop and Mobile) | 11d | 2013-01-14 | 2013-01-28 | 85d |  |
| 85 |  | Desktop Only Changes | 1d | 2013-01-14 | 2013-01-14 | 95d |  |
| 86 |  | Enter rules and data into database | 1d | 2013-01-14 | 2013-01-14 | 95d |  |
| 87 |  | Unit Test (Phase 2 to test code against UI) | 11d | 2013-01-14 | 2013-01-28 | 85d |  |
| 88 |  | Code review | 0.5d | 2013-01-14 | 2013-01-14 | 95.5d |  |
| 89 |  | OREG development complete | 0d | 2013-01-14 | 2013-01-14 | 96d |  |
| 90 | 6.8.2 | **Jira Tickets** | 11d | 2013-01-14 | 2013-01-28 | 85d |  |
| 91 | 6.8.2.1 | **Bundle 1** | 11d | 2013-01-14 | 2013-01-28 | 85d |  |
| 92 |  | 1050-Prod: Students with enroll status = FS can access oreg/fixing summary report so fss students won't be counted. | 3d | 2013-01-14 | 2013-01-16 | 93d |  |
| 93 |  | 1047-Prod: Term address in OREG not in sycnh with websis | 5d | 2013-01-14 | 2013-01-18 | 91d |  |
| 94 |  | 1055-Old phone number appearing on addressess | 11d | 2013-01-14 | 2013-01-28 | 85d |  |
| 95 | 6.8.2.2 | **Bundle 2** | 6d | 2013-01-14 | 2013-01-21 | 90d |  |
| 96 |  | 1036-Advisor landing page: status column sort error | 6d | 2013-01-14 | 2013-01-21 | 90d |  |
| 97 |  | 1042-Change approval process for mobile approvals | 2d | 2013-01-14 | 2013-01-15 | 94d |  |
| 98 |  | 1046-Prod: Freshman Folder link not working for admins | 2d | 2013-01-14 | 2013-01-15 | 94d |  |
| 99 |  | 1052-GASP status adjustment | 2d | 2013-01-14 | 2013-01-15 | 94d |  |
| 100 |  | 1054-Auto save when subject is added | 1d | 2013-01-14 | 2013-01-14 | 95d |  |
| 101 |  | 1053-Adjust messaging for 18.01A and 18.02A (includes mobile) | 2d | 2013-01-14 | 2013-01-15 | 94d |  |
| 102 |  | 1056--Report Summary By Date CSV and PDF Downloads Incorrect | 1d | 2013-01-14 | 2013-01-14 | 95d |  |
| 103 |  | Jira development complete | 0d | 2013-01-14 | 2013-01-14 | 96d |  |
| 104 |  | Development of new requirements for spring messaging | 9d | 2013-01-14 | 2013-01-24 | 87d |  |
| 105 | 6.9 | **Test Preparation** | 25d? | 2013-01-14 | 2013-02-15 | 71d |  |
| 106 |  | Identify data needs - 1st draft | 5d | 2013-01-14 | 2013-01-18 | 91d |  |
| 107 |  | Build test suite in QC | 2d | 2013-01-14 | 2013-02-01 | 81.6d |  |
| 108 |  | Write test cases | 15d | 2013-01-14 | 2013-02-01 | 81d |  |
| 109 |  | Review test cases with team | 1d? | 2013-01-14 | 2013-01-14 | 95d |  |
| 110 |  | Update test cases based on feedback | 25d | 2013-01-14 | 2013-02-15 | 71d |  |
| 111 |  | Identify data needs - final draft | 25d | 2013-01-14 | 2013-02-15 | 71d |  |
| 112 |  | PRDE is rolled to fall (spring population available) | 1d | 2013-01-14 | 2013-01-14 | 95d |  |
| 113 |  | Refresh TEST database | 1d | 2013-01-14 | 2013-01-14 | 95d |  |
| 114 |  | Do data mining | 13d | 2013-01-14 | 2013-01-30 | 83d |  |
| 115 |  | Test preparation complete | 0d | 2013-01-14 | 2013-01-14 | 96d |  |
| 116 |  | Write test cases for new requirements for spring messaging (includes data requirements analysis) | 5d | 2013-01-14 | 2013-01-18 | 91d |  |
| 117 | 6.10 | **Systems Integration Test** | 15d | 2013-01-14 | 2013-02-01 | 81d |  |
| 118 | 6.10.1 | **OREG** | 15d | 2013-01-14 | 2013-02-01 | 81d |  |
| 119 |  | Execute test cases | 15d | 2013-01-14 | 2013-02-01 | 81d |  |
| 120 |  | Bugfixing | 9d | 2013-01-14 | 2013-01-24 | 87d |  |
| 121 | 6.10.2 | **Jira tickets** | 12d | 2013-01-14 | 2013-01-29 | 84d |  |
| 122 | 6.10.2.1 | **Bundle 1** | 12d | 2013-01-14 | 2013-01-29 | 84d |  |
| 123 |  | Execute test cases | 12d | 2013-01-14 | 2013-01-29 | 84d |  |
| 124 |  | Bugfixing | 11d | 2013-01-14 | 2013-01-28 | 85d |  |
| 125 | 6.10.2.2 | **Bundle 2** | 11d | 2013-01-14 | 2013-01-28 | 85d |  |
| 126 |  | Execute test cases | 11d | 2013-01-14 | 2013-01-28 | 85d |  |
| 127 |  | Bugfixing | 11d | 2013-01-14 | 2013-01-28 | 85d |  |
| 128 |  | Regression Testing | 15d | 2013-01-14 | 2013-02-01 | 81d |  |
| 129 |  | SIT of new requirements for spring messaging | 4d | 2013-01-14 | 2013-01-17 | 92d |  |
| 130 |  | End to end testing (includes 1052 and RT 2107132 (gasp3 lock script)) | 2d | 2013-01-14 | 2013-01-15 | 94d |  |
| 131 |  | Load Testing | 1d | 2013-01-14 | 2013-01-14 | 95d |  |
| 132 |  | User Acceptance Test | 1d? | 2013-01-14 | 2013-01-14 | 95d |  |
| 133 | 6.16 | **Deployment Preparation** | 13d? | 2013-01-14 | 2013-01-30 | 83d |  |
| 134 |  | Create deployment plan | 5d | 2013-01-14 | 2013-01-18 | 91d |  |
| 135 |  | Review deployment plan with participants | 1d? | 2013-01-14 | 2013-01-14 | 95d |  |
| 136 |  | Create registration support plan | 13d | 2013-01-14 | 2013-01-30 | 83d |  |
| 137 |  | Go-live | 0d | 2013-01-14 | 2013-01-14 | 96d |  |
| 138 |  | Prod smoke test | 5d | 2013-01-14 | 2013-01-18 | 91d |  |
| 139 |  | Registration opens | 0d | 2013-01-14 | 2013-01-14 | 96d |  |
| 140 |  | Registration support | 10d | 2013-01-14 | 2013-01-25 | 86d |  |

## Version 2 (saved 2013-02-22)

Last finish stays 2013-05-28.

Added:

| ID | Task | Duration | Start | Finish | Predecessors | Resources |
| --- | --- | --- | --- | --- | --- | --- |
| 17 | IAP | 4d | 2013-03-04 | 2013-03-07 | 16FS+2d | Seth [25%] |
| 47 | QA bug fix testing | 3d | 2013-03-25 | 2013-03-27 | 46 | Debra [25%] |

Changed:

| ID | Task | Start | Finish | Duration | Complete | Total float | Predecessors | Other |
| --- | --- | --- | --- | --- | --- | --- | --- | --- |
| 2 | **Upgrade of Existing CSF Apps to CSF 2.0** |  |  |  | 11% → 10% |  |  |  |
| 10 | **Testing** |  | 2013-02-28 → 2013-03-07 (+7d) | 34d? → 39d? |  | 62d → 57d |  |  |
| 15 | **BA Testing** |  | 2013-02-27 → 2013-03-07 (+8d) | 3d? → 9d? |  | 62d → 56d |  |  |
| 16 | Sponsor Billing |  |  |  |  | 62d → 56d |  | was named IAP and Sponsor Billing; resources Seth [25%]; Faith [25%] → Faith [25%] |
| 38 | **PE REG Upgrade** |  | 2013-03-14 → 2013-04-02 (+19d) | 44d? → 57d? | 17% → 9% | 52d → 39d |  |  |
| 39 | **Phase I - Java 6, Touchstone, and CSF Enabling** |  | 2013-03-14 → 2013-04-02 (+19d) | 26d? → 39d? | 20% → 10% | 52d → 39d |  |  |
| 40 | **Development** |  | 2013-03-07 → 2013-03-15 (+8d) | 21d → 27d | 25% → 19% | 52d → 39d |  |  |
| 42 | Perform upgrade | 2013-02-14 A | 2013-02-21 → 2013-02-25 (+4d) | 5d → 7d |  | 52d → 39d |  |  |
| 43 | Unit test changes | 2013-02-22 → 2013-02-26 (+4d) | 2013-03-07 → 2013-03-15 (+8d) | 10d → 14d |  | 52d → 39d |  |  |
| 44 | **Testing** | 2013-03-08 → 2013-02-20 (-16d) | 2013-03-13 → 2013-04-01 (+19d) | 4d? → 29d? |  | 52d → 39d |  |  |
| 45 | Test planning | 2013-03-08 → 2013-02-20 (-16d) | 2013-03-08 → 2013-03-07 (-1d) | 1d? → 12d |  | 52d → 45d | 43 → 42SS+4d | resources none → Debra [25%] |
| 46 | QA testing | 2013-03-11 → 2013-03-18 (+7d) | 2013-03-11 → 2013-03-22 (+11d) | 1d? → 5d |  | 52d → 39d | 45 → 45, 43 | resources none → Debra [25%] |
| 48 | Load testing | 2013-03-12 → 2013-03-28 (+16d) | 2013-03-12 → 2013-03-28 (+16d) |  |  | 52d → 41d | 46 → 47 | resources none → Ram |
| 49 | User testing | 2013-03-13 → 2013-04-01 (+19d) | 2013-03-13 → 2013-04-01 (+19d) |  |  | 52d → 39d | 48 → 47FS+2d | was named User |
| 50 | Go-live | 2013-03-14 → 2013-04-02 (+19d) | 2013-03-14 → 2013-04-02 (+19d) |  |  | 52d → 39d |  |  |
| 51 | **Phase II - Full CSF Upgrade** |  | 2013-03-11 → 2013-03-19 (+8d) | 41d? → 47d? |  | 55d → 49d |  |  |
| 52 | **Development** | 2013-03-08 → 2013-03-18 (+10d) | 2013-03-11 → 2013-03-19 (+8d) |  |  | 54d → 48d |  |  |
| 53 | Perform full upgrade | 2013-03-08 → 2013-03-18 (+10d) | 2013-03-08 → 2013-03-18 (+10d) |  |  | 54d → 48d |  |  |
| 54 | Unit test changes | 2013-03-11 → 2013-03-19 (+8d) | 2013-03-11 → 2013-03-19 (+8d) |  |  | 54d → 48d |  |  |
| 59 | PE REG upgrade complete | 2013-03-14 → 2013-04-02 (+19d) | 2013-03-14 → 2013-04-02 (+19d) |  |  | 52d → 39d |  |  |

## Version 3 (saved 2013-02-27)

Last finish 2013-05-28 → 2013-06-14 (+17d). Complete tasks 3 → 6.

Added:

| ID | Task | Duration | Start | Finish | Predecessors | Constraint | Resources |
| --- | --- | --- | --- | --- | --- | --- | --- |
| 33 | OSE Applications | 0d | 2013-01-14 | 2013-01-14 |  |  |  |
| 69 | **Deployment Preparation** | 11d | 2013-04-29 | 2013-05-13 |  |  |  |
| 70 | Create deployment plan | 5d | 2013-04-29 | 2013-05-03 | 68SS |  | René |
| 71 | Review deployment plan with participants | 1d | 2013-05-06 | 2013-05-06 | 70 |  | René |
| 72 | Create registration support plan | 5d | 2013-05-07 | 2013-05-13 | 71 |  | René |
| 78 | **Functional Specs** | 3d? | 2013-02-25 A | 2013-02-27 |  |  |  |
| 79 | Write functional specs | 1d? | 2013-02-25 A | 2013-02-25 |  |  | Seth |
| 80 | Have team review of functional specs | 1d? | 2013-02-26 | 2013-02-26 | 79 |  | Seth |
| 81 | Get sponsor approval of specs | 1d? | 2013-02-27 | 2013-02-27 | 80 |  | Seth |
| 82 | Functional specs complete | 0d | 2013-02-27 | 2013-02-27 | 81 |  | Seth |
| 91 | Registration opens | 0d | 2013-06-03 | 2013-06-03 |  | start no earlier than 2013-06-03 | Peter |
| 92 | Registration support | 10d | 2013-06-03 | 2013-06-14 | 91 |  | René |

Removed: 75 Requirements; 76 Functional Specification; 77 Technical Analysis and Design - Spring Messages; 78 Write Technical Specification; 79 Review Technical Specification with Technical Team; 80 Update Specification based on feedback; 81 Technical Analysis and Design Complete; 82 Technical Analysis and Design - Rules Engine/OREG Decoupling; 83 Write Technical Specification; 84 Development; 85 OREG; 86 Rules Engine/OREG Decoupling and integration testing; 87 Common Changes (Desktop and Mobile); 88 Desktop Only Changes; 89 Enter rules and data into database; 90 Unit Test (Phase 2 to test code against UI); 91 Code review; 92 OREG development complete; 93 Jira Tickets; 94 Bundle 1; 95 1050-Prod: Students with enroll status = FS can access oreg/fixing summary report so fss students won't be counted.; 96 1047-Prod: Term address in OREG not in sycnh with websis; 97 1055-Old phone number appearing on addressess; 98 Bundle 2; 99 1036-Advisor landing page: status column sort error; 100 1042-Change approval process for mobile approvals; 101 1046-Prod: Freshman Folder link not working for admins; 102 1052-GASP status adjustment; 103 1054-Auto save when subject is added; 104 1053-Adjust messaging for 18.01A and 18.02A (includes mobile); 105 1056--Report Summary By Date CSV and PDF Downloads Incorrect; 106 Jira development complete; 107 Development of new requirements for spring messaging; 108 Test Preparation; 109 Identify data needs - 1st draft; 110 Build test suite in QC; 111 Write test cases; 112 Review test cases with team; 113 Update test cases based on feedback; 114 Identify data needs - final draft; 115 PRDE is rolled to fall (spring population available); 116 Refresh TEST database; 117 Do data mining; 118 Test preparation complete; 119 Write test cases for new requirements for spring messaging (includes data requirements analysis); 120 Systems Integration Test; 121 OREG; 122 Execute test cases; 123 Bugfixing; 124 Jira tickets; 125 Bundle 1; 126 Execute test cases; 127 Bugfixing; 128 Bundle 2; 129 Execute test cases; 130 Bugfixing; 131 Regression Testing; 132 SIT of new requirements for spring messaging; 133 End to end testing (includes 1052 and RT 2107132 (gasp3 lock script)); 134 Load Testing; 135 User Acceptance Test; 140 Go-live

Changed:

| ID | Task | Start | Finish | Duration | Complete | Total float | Predecessors | Other |
| --- | --- | --- | --- | --- | --- | --- | --- | --- |
| 2 | **Upgrade of Existing CSF Apps to CSF 2.0** |  |  |  | 10% → 29% | 56d → 70d |  |  |
| 3 | **Development** |  |  |  | 20% → 60% | 56d → 70d |  |  |
| 4 | Upgrade IAP | 2013-02-14 A | 2013-02-20 → 2013-02-25 A (+5d) | 4d → 7d | 0% → 100% | 60d → none |  |  |
| 5 | Upgrade Subject Evaluation Report/OSE Report | 2013-02-26 A | 2013-03-01 → 2013-02-26 A (-3d) | 4d → 1d | 0% → 100% | 60d → none |  | was named Upgrade Subject Evaluation |
| 8 | Upgrade Response Rate Report |  |  |  |  |  |  | was named Upgrade Subject Evaluation Report |
| 11 | **Test Planning** |  | 2013-02-25 → 2013-03-01 (+4d) | 4d? → 8d |  | 56d → 71d |  |  |
| 13 | OSE Applications | 2013-02-25 → 2013-02-27 (+2d) | 2013-02-25 → 2013-03-01 (+4d) | 1d? → 3d |  | 63d → 59d | 12 → 12FS+2d | was named OFS Applications |
| 14 | Test Planning Complete | 2013-02-25 → 2013-03-01 (+4d) | 2013-02-25 → 2013-03-01 (+4d) |  |  | 64d → 60d |  |  |
| 18 | OSE Applications | 2013-02-26 → 2013-03-04 (+6d) | 2013-02-26 → 2013-03-04 (+6d) |  |  | 63d → 59d |  | was named OFS Applications |
| 19 | BA Testing Complete | 2013-02-27 → 2013-03-04 (+5d) | 2013-02-27 → 2013-03-04 (+5d) |  |  | 62d → 73d |  |  |
| 21 | Upgrade Subject Evaluation Report/OSE Report |  |  |  |  |  |  | was named Subject Evaluation |
| 23 | Upgrade Response Rate Report |  |  |  |  |  |  | was named Subject Evaluation Report |
| 24 | UAT Complete |  |  |  |  | 94d → 108d | 32, 21, 31, 22, 23 → 21, 22, 23 |  |
| 25 | Testing Efforts Complete | 2013-02-28 → 2013-03-05 (+5d) | 2013-02-28 → 2013-03-05 (+5d) |  |  | 62d → 59d |  |  |
| 30 | **Go-live** |  | 2013-01-14 → 2013-03-07 (+52d) | 1d? → 39d |  | 95d → 71d |  |  |
| 31 | Sponsor Billing | 2013-01-14 → 2013-03-01 (+46d) | 2013-01-14 → 2013-03-01 (+46d) | 1d? → 0d |  | 94d → 61d | none → 16FS+2d |  |
| 32 | IAP | 2013-01-14 → 2013-03-07 (+52d) | 2013-01-14 → 2013-03-07 (+52d) | 1d? → 0d |  | 94d → 57d | none → 17 |  |
| 34 | Upgrade of Existing CSF Apps to CSF 2.0 Complete | 2013-01-14 → 2013-03-07 (+52d) | 2013-01-14 → 2013-03-07 (+52d) |  |  | 95d → 57d | 74 → 31, 32, 33 |  |
| 60 | **OREG to Conversion to CSF 2.0** | 2013-02-11 A | 2013-05-28 → 2013-06-14 (+17d) | 76d → 90d | 0% → 13% |  |  | was named Convert OREG to CSF 2.0 |
| 61 | **Development (including unit testing)** | 2013-02-11 A |  |  | 0% → 35% | 0d → 17d |  |  |
| 62 | Phase 1 - Required as-is , high priority (A/D and OREG) | 2013-02-11 A | 2013-02-22 A |  | 0% → 100% | 0d → none |  |  |
| 63 | Phase 2 - Medium priority validation and messaging | 2013-02-25 A |  |  | 0% → 20% | 0d → 16d |  |  |
| 66 | OREG conversion development complete |  |  |  |  | 0d → 17d |  | was named Development complete |
| 68 | UAT |  | 2013-05-24 → 2013-05-17 (-7d) | 20d → 15d |  | 0d → 17d |  | resources Brian → Peter [25%] |
| 73 | Go-live | 2013-05-28 → 2013-05-21 (-7d) | 2013-05-28 → 2013-05-21 (-7d) |  |  | 0d → 18d | none → 68FS+2d | constraint start no earlier than 2013-05-28 → none |
| 74 | Prod smoke test | 2013-01-14 → 2013-05-21 (+127d) | 2013-01-14 → 2013-05-21 (+127d) | 1d? → 0d |  | 95d → 18d | none → 73 | resources none → Peter |
| 75 | Registration opens | 2013-01-14 → 2013-06-03 (+140d) | 2013-01-14 → 2013-06-03 (+140d) |  |  | 96d → 0d |  | constraint none → start no earlier than 2013-06-03; resources none → Peter |
| 76 | Registration support | 2013-01-14 → 2013-06-03 (+140d) | 2013-01-25 → 2013-06-14 (+140d) |  |  | 86d → 0d | none → 75 | resources none → René |
| 77 | **Notes Utility Beta** | 2013-01-14 → 2013-02-25 A (+42d) | 2013-05-28 → 2013-06-14 (+17d) | 96d? → 80d? |  |  |  |  |
| 83 | Development |  | 2013-04-01 → 2013-04-26 (+25d) | 1d? → 19d |  | 39d → 17d | 61 → 61, 82 |  |
| 84 | UAT | 2013-01-14 → 2013-04-29 (+105d) | 2013-01-14 → 2013-05-17 (+123d) | 1d? → 15d |  | 95d → 17d | none → 83 | resources none → Peter [25%] |
| 85 | **Deployment Preparation** | 2013-01-14 → 2013-04-29 (+105d) | 2013-01-30 → 2013-05-13 (+103d) | 13d? → 11d |  | 83d → 24d |  |  |
| 86 | Create deployment plan | 2013-01-14 → 2013-04-29 (+105d) | 2013-01-18 → 2013-05-03 (+105d) |  |  | 91d → 24d | none → 70SS | resources none → René |
| 87 | Review deployment plan with participants | 2013-01-14 → 2013-05-06 (+112d) | 2013-01-14 → 2013-05-06 (+112d) | 1d? → 1d |  | 95d → 24d | none → 86 | resources none → René |
| 88 | Create registration support plan | 2013-01-14 → 2013-05-07 (+113d) | 2013-01-30 → 2013-05-13 (+103d) | 13d → 5d |  | 83d → 24d | none → 87 | resources none → René |
| 89 | Go-live | 2013-05-28 → 2013-05-21 (-7d) | 2013-05-28 → 2013-05-21 (-7d) |  |  | 0d → 18d | none → 84FS+2d | constraint start no earlier than 2013-05-28 → none |
| 90 | Prod smoke test | 2013-01-14 → 2013-05-21 (+127d) | 2013-01-18 → 2013-05-21 (+123d) | 5d → 0d |  | 91d → 18d | none → 89 | resources none → Peter |

## Version 4 (saved 2013-02-28)

Last finish stays 2013-06-14. Complete tasks 6 → 10.

Changed:

| ID | Task | Start | Finish | Duration | Complete | Total float | Predecessors | Other |
| --- | --- | --- | --- | --- | --- | --- | --- | --- |
| 2 | **Upgrade of Existing CSF Apps to CSF 2.0** |  | 2013-03-08 → 2013-03-07 (-1d) | 40d? → 39d? | 29% → 51% | 70d → 71d |  |  |
| 3 | **Development** |  | 2013-03-08 → 2013-03-06 (-2d) | 18d → 16d | 60% → 78% | 70d → 58d |  |  |
| 7 | Upgrade Survey Engine | 2013-02-26 A | 2013-03-01 → 2013-02-27 A (-2d) | 4d → 2d | 0% → 100% | 55d → none |  |  |
| 8 | Upgrade Response Rate Report | 2013-03-05 → 2013-03-01 (-4d) | 2013-03-08 → 2013-03-06 (-2d) |  |  | 55d → 57d |  |  |
| 9 | Upgrades complete | 2013-03-08 → 2013-03-06 (-2d) | 2013-03-08 → 2013-03-06 (-2d) |  |  | 56d → 58d |  |  |
| 10 | **Testing** | 2013-01-14 A |  |  | 0% → 33% | 71d → 70d |  |  |
| 11 | **Test Planning** | 2013-02-20 A |  |  | 0% → 50% | 71d → 60d |  |  |
| 12 | IAP and Sponsor Billing | 2013-02-20 A | 2013-02-22 A |  | 0% → 100% | 62d → none |  |  |
| 15 | **BA Testing** | 2013-02-25 A |  |  | 0% → 38% | 71d → 70d |  |  |
| 16 | Sponsor Billing | 2013-02-25 A | 2013-02-27 A |  | 0% → 100% | 56d → none |  |  |
| 21 | Subject Evaluation Report/OSE Report |  |  |  |  |  |  | was named Upgrade Subject Evaluation Report/OSE Report |
| 23 | Response Rate Report |  |  |  |  |  |  | was named Upgrade Response Rate Report |
| 38 | **PE REG Upgrade** |  |  |  | 9% → 39% |  |  |  |
| 39 | **Phase I - Java 6, Touchstone, and CSF Enabling** |  |  |  | 10% → 43% |  |  |  |
| 40 | **Development** |  |  |  | 19% → 54% |  |  |  |
| 42 | Perform upgrade |  | 2013-02-25 → 2013-02-27 A (+2d) | 7d → 9d | 0% → 100% | 52d → none |  |  |
| 43 | Unit test changes | 2013-02-26 → 2013-02-28 (+2d) |  | 14d → 12d |  | 39d → 52d |  |  |
| 44 | **Testing** | 2013-02-20 A |  |  | 0% → 32% |  |  |  |
| 45 | Test planning | 2013-02-20 A |  |  | 0% → 58% | 45d → 59d |  |  |
| 48 | Load testing | 2013-03-28 → 2013-03-21 (-7d) | 2013-03-28 → 2013-03-21 (-7d) | 1d? → 1d |  | 41d → 61d | 47 → 46FS-2d | resources Ram → Steve [25%] |
| 78 | **Functional Specs** |  | 2013-02-27 → 2013-03-19 (+20d) | 3d? → 17d? |  | 40d → 26d |  |  |
| 79 | Write functional specs |  | 2013-02-25 → 2013-03-15 (+18d) | 1d? → 15d |  | 40d → 26d |  |  |
| 80 | Have team review of functional specs | 2013-02-26 → 2013-03-18 (+20d) | 2013-02-26 → 2013-03-18 (+20d) |  |  | 40d → 26d |  |  |
| 81 | Get sponsor approval of specs | 2013-02-27 → 2013-03-19 (+20d) | 2013-02-27 → 2013-03-19 (+20d) |  |  | 40d → 26d |  |  |
| 82 | Functional specs complete | 2013-02-27 → 2013-03-19 (+20d) | 2013-02-27 → 2013-03-19 (+20d) |  |  | 40d → 26d |  |  |

## Version 5 (saved 2013-03-01)

Last finish stays 2013-06-14. Complete tasks 10 → 15.

Removed: 22 Survey Engine; 23 Response Rate Report; 28 Review deployment plan with participants; 29 Create registration support plan

Changed:

| ID | Task | Start | Finish | Duration | Complete | Total float | Predecessors | Other |
| --- | --- | --- | --- | --- | --- | --- | --- | --- |
| 2 | **Upgrade of Existing CSF Apps to CSF 2.0** | 2013-01-14 A → 2013-02-13 A (+30d) | 2013-03-07 → 2013-03-08 (+1d) | 39d? → 18d | 51% → 65% | 71d → 70d |  |  |
| 3 | **Development** |  | 2013-03-06 → 2013-02-27 A (-7d) | 16d → 11d | 78% → 100% | 58d → none |  |  |
| 8 | Upgrade Response Rate Report | 2013-03-01 → 2013-02-22 A (-7d) | 2013-03-06 → 2013-02-25 A (-9d) | 4d → 2d | 0% → 100% | 57d → none |  |  |
| 9 | Upgrades complete | 2013-03-06 → 2013-02-27 A (-7d) | 2013-03-06 → 2013-02-27 A (-7d) |  | 0% → 100% | 58d → none |  |  |
| 10 | **Testing** | 2013-01-14 A → 2013-02-20 A (+37d) | 2013-03-07 → 2013-03-08 (+1d) | 39d? → 13d | 33% → 39% |  |  |  |
| 11 | **Test Planning** |  | 2013-03-01 A |  | 50% → 100% | 60d → none |  |  |
| 12 | Sponsor Billing |  |  |  |  |  |  | was named IAP and Sponsor Billing |
| 13 | OSE Applications | 2013-02-27 A | 2013-03-01 A |  | 0% → 100% | 59d → none |  |  |
| 14 | Test Planning Complete | 2013-03-01 A | 2013-03-01 A |  | 0% → 100% | 60d → none |  |  |
| 15 | **BA Testing** |  | 2013-03-07 → 2013-03-08 (+1d) | 9d? → 10d | 38% → 25% |  |  |  |
| 17 | IAP (includes planning) |  |  |  |  | 56d → 71d |  | was named IAP |
| 18 | OSE Applications |  | 2013-03-04 → 2013-03-08 (+4d) | 1d? → 5d |  | 59d → 70d |  |  |
| 19 | BA Testing Complete | 2013-03-04 → 2013-03-08 (+4d) | 2013-03-04 → 2013-03-08 (+4d) |  |  | 73d → 70d |  |  |
| 20 | **UAT** | 2013-01-14 → 2013-03-04 (+49d) | 2013-01-14 → 2013-03-08 (+53d) | 1d? → 5d |  | 108d → 70d |  |  |
| 21 | OSE Applications | 2013-01-14 → 2013-03-04 (+49d) | 2013-01-14 → 2013-03-08 (+53d) | 1d? → 5d |  | 94d → 70d | none → 18SS | was named Subject Evaluation Report/OSE Report |
| 22 | UAT Complete | 2013-01-14 → 2013-03-08 (+53d) | 2013-01-14 → 2013-03-08 (+53d) |  |  | 108d → 70d | 21, Survey Engine, Response Rate Report → 21 |  |
| 23 | Testing Efforts Complete | 2013-03-05 → 2013-03-08 (+3d) | 2013-03-05 → 2013-03-08 (+3d) | 1d? → 0d |  | 59d → 70d |  |  |
| 24 | **Deployment Preparation** | 2013-01-14 → 2013-03-08 (+53d) | 2013-01-14 → 2013-03-08 (+53d) | 1d? → 0d |  | 109d → 70d |  |  |
| 25 | Get Eamon's approval to move apps to PROD | 2013-01-14 → 2013-03-08 (+53d) | 2013-01-14 → 2013-03-08 (+53d) | 1d? → 0d |  | 94d → 70d | none → 23 | was named Create deployment plan |
| 26 | **Go-live** | 2013-01-14 → 2013-02-28 A (+45d) | 2013-03-07 → 2013-03-08 (+1d) | 39d → 7d | 0% → 99% | 57d → 70d |  |  |
| 27 | Sponsor Billing | 2013-03-01 → 2013-02-28 A (-1d) | 2013-03-01 → 2013-02-28 A (-1d) | 0d → 1d | 0% → 100% | 61d → none |  |  |
| 29 | OSE Applications | 2013-01-14 → 2013-03-08 (+53d) | 2013-01-14 → 2013-03-08 (+53d) |  |  | 96d → 70d | none → 18, 21 |  |
| 30 | Upgrade of Existing CSF Apps to CSF 2.0 Complete | 2013-03-07 → 2013-03-08 (+1d) | 2013-03-07 → 2013-03-08 (+1d) |  |  | 57d → 70d |  |  |
| 34 | **PE REG Upgrade** |  |  |  | 39% → 43% |  |  |  |
| 35 | **Phase I - Java 6, Touchstone, and CSF Enabling** |  |  |  | 43% → 47% |  |  |  |
| 36 | **Development** |  |  |  | 54% → 62% |  |  |  |
| 39 | Unit test changes | 2013-02-28 A |  |  | 0% → 17% | 52d → 53d |  |  |

## Version 6 (saved 2013-03-08)

Last finish stays 2013-06-14. Complete tasks 15 → 19.

Changed:

| ID | Task | Start | Finish | Duration | Complete | Total float |
| --- | --- | --- | --- | --- | --- | --- |
| 2 | **Upgrade of Existing CSF Apps to CSF 2.0** |  |  |  | 65% → 90% |  |
| 10 | **Testing** |  | 2013-03-08 → 2013-03-07 (-1d) | 13d → 12d | 39% → 81% | 70d → 71d |
| 15 | **BA Testing** |  | 2013-03-08 → 2013-03-07 (-1d) | 10d → 9d | 25% → 64% | 70d → 71d |
| 18 | OSE Applications | 2013-03-04 A | 2013-03-08 → 2013-03-07 A (-1d) | 5d → 4d | 0% → 100% | 70d → none |
| 19 | BA Testing Complete | 2013-03-08 → 2013-03-07 (-1d) | 2013-03-08 → 2013-03-07 (-1d) |  |  | 70d → 71d |
| 20 | **UAT** | 2013-03-04 A | 2013-03-08 → 2013-03-07 A (-1d) | 5d → 4d | 0% → 100% | 70d → none |
| 21 | OSE Applications | 2013-03-04 A | 2013-03-08 → 2013-03-07 A (-1d) | 5d → 4d | 0% → 100% | 70d → none |
| 22 | UAT Complete | 2013-03-08 → 2013-03-07 A (-1d) | 2013-03-08 → 2013-03-07 A (-1d) |  | 0% → 100% | 70d → none |
| 23 | Testing Efforts Complete | 2013-03-08 → 2013-03-07 (-1d) | 2013-03-08 → 2013-03-07 (-1d) |  |  | 70d → 71d |
| 24 | **Deployment Preparation** | 2013-03-08 → 2013-03-07 (-1d) | 2013-03-08 → 2013-03-07 (-1d) |  |  | 70d → 71d |
| 25 | Get Eamon's approval to move apps to PROD | 2013-03-08 → 2013-03-07 (-1d) | 2013-03-08 → 2013-03-07 (-1d) |  |  | 70d → 71d |
| 29 | OSE Applications | 2013-03-08 → 2013-03-07 A (-1d) | 2013-03-08 A | 0d → 1d | 0% → 100% | 70d → none |
| 34 | **PE REG Upgrade** |  |  |  | 43% → 52% |  |
| 35 | **Phase I - Java 6, Touchstone, and CSF Enabling** |  |  |  | 47% → 57% |  |
| 36 | **Development** |  |  |  | 62% → 81% |  |
| 39 | Unit test changes |  |  |  | 17% → 58% |  |
| 56 | **OREG to Conversion to CSF 2.0** |  |  |  | 13% → 20% |  |
| 57 | **Development (including unit testing)** |  |  |  | 35% → 56% |  |
| 59 | Phase 2 - Medium priority validation and messaging |  |  |  | 20% → 67% |  |

## Version 7 (saved 2013-03-13)

Last finish stays 2013-06-14. Complete tasks 19 → 20.

Changed:

| ID | Task | Start | Finish | Duration | Complete | Total float | Other |
| --- | --- | --- | --- | --- | --- | --- | --- |
| 2 | **Upgrade of Existing CSF Apps to CSF 2.0** |  | 2013-03-08 → 2013-03-15 (+7d) | 18d → 23d | 90% → 96% | 70d → 65d |  |
| 10 | **Testing** |  | 2013-03-07 → 2013-03-15 (+8d) | 12d → 18d | 81% → 93% | 71d → 65d |  |
| 15 | **BA Testing** |  | 2013-03-07 → 2013-03-15 (+8d) | 9d → 15d | 64% → 88% | 71d → 65d |  |
| 17 | IAP (includes planning) | 2013-03-04 A | 2013-03-07 → 2013-03-15 (+8d) | 4d → 10d | 0% → 80% | 71d → 65d |  |
| 26 | **Go-live** |  | 2013-03-08 → 2013-03-15 (+7d) | 7d → 12d |  | 70d → 65d |  |
| 28 | IAP | 2013-03-07 → 2013-03-15 (+8d) | 2013-03-07 → 2013-03-15 (+8d) |  |  | 71d → 65d |  |
| 30 | Upgrade of Existing CSF Apps to CSF 2.0 Complete | 2013-03-08 → 2013-03-15 (+7d) | 2013-03-08 → 2013-03-15 (+7d) |  |  | 70d → 65d |  |
| 34 | **PE REG Upgrade** |  |  |  | 52% → 67% |  |  |
| 35 | **Phase I - Java 6, Touchstone, and CSF Enabling** |  |  |  | 57% → 73% |  |  |
| 36 | **Development** |  |  |  | 81% → 92% |  |  |
| 39 | Unit test changes |  |  |  | 58% → 83% |  |  |
| 40 | **Testing** |  |  |  | 32% → 55% |  |  |
| 41 | Test planning |  | 2013-03-07 A |  | 58% → 100% | 59d → none |  |
| 56 | **OREG to Conversion to CSF 2.0** |  |  |  | 20% → 23% |  |  |
| 57 | **Development (including unit testing)** |  |  |  | 56% → 65% |  |  |
| 59 | Phase 2 - Medium priority validation and messaging |  |  |  | 67% → 87% |  |  |
| 73 | **Notes Utility Beta** |  |  | 80d? → 80d |  |  |  |
| 74 | **Functional Specs** |  | 2013-03-19 → 2013-03-21 (+2d) | 17d? → 18.25d |  | 26d → 24.75d |  |
| 75 | Write functional specs |  | 2013-03-15 → 2013-03-20 (+5d) | 15d → 18d |  | 26d → 24.75d |  |
| 76 | Have team review of functional specs | 2013-03-18 → 2013-03-21 (+3d) | 2013-03-18 → 2013-03-21 (+3d) | 1d? → 0.25d |  | 26d → 24.75d |  |
| 77 | Send specs to sponsors for approval | 2013-03-19 → 2013-03-21 (+2d) | 2013-03-19 → 2013-03-21 (+2d) | 1d? → 0d |  | 26d → 24.75d | was named Get sponsor approval of specs |
| 78 | Functional specs complete | 2013-03-19 → 2013-03-21 (+2d) | 2013-03-19 → 2013-03-21 (+2d) |  |  | 26d → 24.75d |  |

## Version 8 (saved 2013-03-18)

Last finish stays 2013-06-14. Complete tasks 20 → 21.

Changed:

| ID | Task | Start | Finish | Duration | Complete | Total float | Predecessors |
| --- | --- | --- | --- | --- | --- | --- | --- |
| 2 | **Upgrade of Existing CSF Apps to CSF 2.0** |  | 2013-03-15 → 2013-04-08 (+24d) | 23d → 39d | 96% → 77% | 65d → 49d |  |
| 10 | **Testing** |  | 2013-03-15 → 2013-04-05 (+21d) | 18d → 33d | 93% → 67% | 65d → 50d |  |
| 15 | **BA Testing** |  | 2013-03-15 → 2013-04-05 (+21d) | 15d → 30d | 88% → 56% | 65d → 50d |  |
| 17 | IAP (includes planning) |  | 2013-03-15 → 2013-04-05 (+21d) | 10d → 25d | 80% → 44% | 65d → 49d |  |
| 26 | **Go-live** |  | 2013-03-15 → 2013-04-08 (+24d) | 12d → 28d |  | 65d → 49d |  |
| 28 | IAP | 2013-03-15 → 2013-04-08 (+24d) | 2013-03-15 → 2013-04-08 (+24d) |  |  | 65d → 49d | 17 → 17FS+1d |
| 30 | Upgrade of Existing CSF Apps to CSF 2.0 Complete | 2013-03-15 → 2013-04-08 (+24d) | 2013-03-15 → 2013-04-08 (+24d) |  |  | 65d → 49d |  |
| 34 | **PE REG Upgrade** |  |  |  | 67% → 72% |  |  |
| 35 | **Phase I - Java 6, Touchstone, and CSF Enabling** |  |  |  | 73% → 80% |  |  |
| 36 | **Development** |  | 2013-03-15 A |  | 92% → 100% | 53d → none |  |
| 39 | Unit test changes |  | 2013-03-15 A |  | 83% → 100% | 53d → none |  |
| 40 | **Testing** |  |  |  | 55% → 59% |  |  |
| 42 | QA testing | 2013-03-18 A |  |  | 0% → 20% |  |  |
| 56 | **OREG to Conversion to CSF 2.0** |  |  |  | 23% → 31% |  |  |
| 57 | **Development (including unit testing)** |  |  |  | 65% → 69% | 17d → 18d |  |
| 59 | Phase 2 - Medium priority validation and messaging |  | 2013-03-15 → 2013-03-20 (+5d) | 15d → 18d | 87% → 89% | 16d → 25d |  |
| 60 | Phase 3 - Stabilize JAR and rafactor CSF dependencies | 2013-03-18 → 2013-03-13 A (-5d) |  | 5d → 8d | 0% → 50% | 16d → 23d | 59 → 59FS-6d |
| 61 | Phase 4 - Modify OREG to use new JAR and upgrade to CSF 2.0 | 2013-03-25 → 2013-03-13 A (-12d) |  | 5d → 13d | 0% → 31% |  | 60 → 60SS |
| 74 | **Functional Specs** |  | 2013-03-21 → 2013-03-26 (+5d) | 18.25d → 21.25d |  | 24.75d → 21.75d |  |
| 75 | Write functional specs |  | 2013-03-20 → 2013-03-21 (+1d) | 18d → 19d |  | 24.75d → 21.75d |  |
| 76 | Have team review of functional specs | 2013-03-21 → 2013-03-22 (+1d) | 2013-03-21 → 2013-03-22 (+1d) |  |  | 24.75d → 21.75d |  |
| 77 | Send specs to sponsors for approval | 2013-03-21 → 2013-03-26 (+5d) | 2013-03-21 → 2013-03-26 (+5d) |  |  | 24.75d → 21.75d | 76 → 76FS+2d |
| 78 | Functional specs complete | 2013-03-21 → 2013-03-26 (+5d) | 2013-03-21 → 2013-03-26 (+5d) |  |  | 24.75d → 21.75d |  |

## Version 9 (saved 2013-03-20)

Last finish stays 2013-06-14. Complete tasks 21 → 23.

Removed: 43 QA bug fix testing

Changed:

| ID | Task | Start | Finish | Duration | Complete | Total float | Predecessors |
| --- | --- | --- | --- | --- | --- | --- | --- |
| 34 | **PE REG Upgrade** |  |  |  | 72% → 70% |  |  |
| 35 | **Phase I - Java 6, Touchstone, and CSF Enabling** |  |  |  | 80% → 76% |  |  |
| 40 | **Testing** |  |  |  | 59% → 54% |  |  |
| 42 | QA testing |  | 2013-03-22 → 2013-03-29 (+7d) | 5d → 10d | 20% → 10% |  |  |
| 43 | Load testing | 2013-03-21 → 2013-03-28 (+7d) | 2013-03-21 → 2013-03-28 (+7d) |  |  | 61d → 56d |  |
| 44 | User testing |  |  |  |  |  | QA bug fix testingFS+2d → 42 |
| 55 | **OREG to Conversion to CSF 2.0** |  |  |  | 31% → 36% |  |  |
| 56 | **Development (including unit testing)** |  |  |  | 69% → 81% |  |  |
| 58 | Phase 2 - Medium priority validation and messaging |  | 2013-03-20 A |  | 89% → 100% | 25d → none |  |
| 59 | Phase 3 - Stabilize JAR and rafactor CSF dependencies |  |  |  | 50% → 75% |  |  |
| 60 | Phase 4 - Modify OREG to use new JAR and upgrade to CSF 2.0 |  |  |  | 31% → 46% |  |  |
| 72 | **Notes Utility Beta** |  |  |  | 0% → 24% |  |  |
| 73 | **Functional Specs** |  |  |  | 0% → 99% |  |  |
| 74 | Write functional specs |  | 2013-03-21 → 2013-03-19 A (-2d) | 19d → 17d | 0% → 100% | 21.75d → none |  |
| 75 | Have team review of functional specs |  |  |  |  |  | 74 → 74FS+2d |

## Version 10 (saved 2013-03-27)

Last finish stays 2013-06-14. Complete tasks 23 → 26.

Changed:

| ID | Task | Start | Finish | Duration | Complete | Total float |
| --- | --- | --- | --- | --- | --- | --- |
| 34 | **PE REG Upgrade** |  | 2013-04-02 → 2013-04-29 (+27d) | 57d? → 76d? | 70% → 61% | 53d → 34d |
| 35 | **Phase I - Java 6, Touchstone, and CSF Enabling** |  | 2013-04-02 → 2013-04-29 (+27d) | 39d? → 58d | 76% → 66% | 53d → 34d |
| 40 | **Testing** |  | 2013-04-01 → 2013-04-26 (+25d) | 29d? → 48d | 54% → 47% | 54d → 35d |
| 42 | QA testing |  | 2013-03-29 → 2013-04-05 (+7d) | 10d → 15d | 10% → 53% | 53d → 34d |
| 43 | Load testing | 2013-03-28 → 2013-04-04 (+7d) | 2013-03-28 → 2013-04-04 (+7d) |  |  | 56d → 51d |
| 44 | User testing | 2013-04-01 → 2013-04-08 (+7d) | 2013-04-01 → 2013-04-26 (+25d) | 1d? → 15d |  | 53d → 34d |
| 45 | Go-live | 2013-04-02 → 2013-04-29 (+27d) | 2013-04-02 → 2013-04-29 (+27d) | 1d? → 1d |  | 53d → 34d |
| 54 | PE REG upgrade complete | 2013-04-02 → 2013-04-29 (+27d) | 2013-04-02 → 2013-04-29 (+27d) |  |  | 53d → 34d |
| 55 | **OREG to Conversion to CSF 2.0** |  |  |  | 36% → 43% |  |
| 56 | **Development (including unit testing)** |  |  |  | 81% → 96% | 18d → 17d |
| 59 | Phase 3 - Stabilize JAR and rafactor CSF dependencies |  | 2013-03-22 A |  | 75% → 100% | 23d → none |
| 60 | Phase 4 - Modify OREG to use new JAR and upgrade to CSF 2.0 |  |  |  | 46% → 85% |  |
| 75 | Have team review of functional specs | 2013-03-22 A | 2013-03-22 A |  | 0% → 100% | 21.75d → none |
| 76 | Send specs to sponsors for approval | 2013-03-26 A | 2013-03-26 A |  | 0% → 100% | 21.75d → none |

## Version 11 (saved 2013-04-01)

Last finish stays 2013-06-14. Complete tasks 26 → 27.

Added:

| ID | Task | Duration | Start | Finish | Predecessors | Resources |
| --- | --- | --- | --- | --- | --- | --- |
| 32 | **Batch Admin** | 50d | 2013-03-22 A | 2013-05-30 |  |  |
| 35 | **Deployment Preparation** | 9.25d | 2013-05-16 | 2013-05-29 |  |  |
| 36 | Create deployment plan | 7d | 2013-05-16 | 2013-05-24 | 34SS+10d | René [25%] |
| 37 | Review deployment plan with participants | 0.25d | 2013-05-28 | 2013-05-28 | 36 | René [25%] |
| 38 | Get business approval | 1d | 2013-05-28 | 2013-05-29 | 37 | René [25%] |
| 39 | Go-live | 0d | 2013-05-30 | 2013-05-30 | 38, 34 |  |

Changed:

| ID | Task | Start | Finish | Duration | Complete | Total float | Predecessors | Other |
| --- | --- | --- | --- | --- | --- | --- | --- | --- |
| 2 | **Upgrade of Existing CSF Apps to CSF 2.0** |  | 2013-04-08 → 2013-04-05 (-3d) | 39d → 38d | 77% → 97% | 49d → 50d |  |  |
| 10 | **Testing** |  | 2013-04-05 → 2013-04-03 (-2d) | 33d → 31d | 67% → 95% |  |  |  |
| 15 | **BA Testing** |  | 2013-04-05 → 2013-04-03 (-2d) | 30d → 28d | 56% → 93% |  |  |  |
| 17 | IAP (includes planning) |  | 2013-04-05 → 2013-04-03 (-2d) | 25d → 23d | 44% → 91% | 49d → 50d |  |  |
| 19 | BA Testing Complete | 2013-03-07 → 2013-03-28 A (+21d) | 2013-03-07 → 2013-03-28 A (+21d) |  | 0% → 100% | 71d → none | 16, 18 → 16, 18, 17 |  |
| 23 | Testing Efforts Complete | 2013-03-07 → 2013-03-28 A (+21d) | 2013-03-07 → 2013-03-28 A (+21d) |  | 0% → 100% | 71d → none |  |  |
| 24 | **Deployment Preparation** | 2013-03-07 → 2013-04-03 (+27d) | 2013-03-07 → 2013-04-03 (+27d) |  |  | 71d → 52d |  |  |
| 25 | Get business approval for IAP | 2013-03-07 → 2013-04-03 (+27d) | 2013-03-07 → 2013-04-03 (+27d) |  |  | 71d → 52d | 23 → 17 | was named Get Eamon's approval to move apps to PROD; resources René → Seth |
| 26 | **Go-live** |  | 2013-04-08 → 2013-04-05 (-3d) | 28d → 27d |  | 49d → 50d |  |  |
| 28 | IAP | 2013-04-08 → 2013-04-05 (-3d) | 2013-04-08 → 2013-04-05 (-3d) |  |  | 49d → 50d | 17FS+1d → 17FS+2d, 25 |  |
| 30 | Upgrade of Existing CSF Apps to CSF 2.0 Complete | 2013-04-08 → 2013-04-05 (-3d) | 2013-04-08 → 2013-04-05 (-3d) |  |  | 49d → 50d |  |  |
| 31 | **Convert SAIS-Common Apps to CSF 2.0** | 2013-01-14 → 2013-03-22 A (+67d) | 2013-01-14 → 2013-05-30 (+136d) | 1d? → 50d |  | 109d → 11d |  |  |
| 33 | Development | 2013-01-14 → 2013-03-22 A (+67d) | 2013-01-14 → 2013-05-01 (+107d) | 1d? → 28d |  | 109d → 11d |  | resources none → Steve [25%] |
| 34 | Testing | 2013-01-14 → 2013-05-02 (+108d) | 2013-01-14 → 2013-05-30 (+136d) | 1d? → 21d |  | 109d → 11d | none → 33 |  |
| 40 | **PE REG Upgrade** |  |  |  | 61% → 65% |  |  |  |
| 41 | **Phase I - Java 6, Touchstone, and CSF Enabling** |  |  |  | 66% → 70% |  |  |  |
| 46 | **Testing** |  |  |  | 47% → 53% |  |  |  |
| 48 | QA testing |  |  |  | 53% → 73% |  |  |  |
| 61 | **OREG to Conversion to CSF 2.0** |  |  |  | 43% → 45% |  |  |  |
| 62 | **Development (including unit testing)** |  | 2013-03-29 → 2013-04-02 (+4d) | 35d → 37d | 96% → 98% | 17d → 18d |  |  |
| 66 | Phase 4 - Modify OREG to use new JAR and upgrade to CSF 2.0 |  | 2013-03-29 → 2013-04-02 (+4d) | 13d → 15d | 85% → 93% | 17d → 18d |  |  |
| 67 | OREG conversion development complete | 2013-03-29 → 2013-04-02 (+4d) | 2013-03-29 → 2013-04-02 (+4d) |  |  | 17d → 18d |  |  |
| 68 | Regression Testing | 2013-04-01 A |  |  | 0% → 4% |  | 67 → 67FS-2d |  |
| 78 | **Notes Utility Beta** |  |  |  | 24% → 29% |  |  |  |
| 79 | **Functional Specs** |  | 2013-03-26 → 2013-04-02 (+7d) | 21.25d → 26.25d |  | 21.75d → 18.75d |  |  |
| 82 | Get sponsor approval on functional spec |  | 2013-03-26 A → 2013-04-02 (+7d) | 0d → 5d | 100% → 95% | none → 18.75d |  | was named Send specs to sponsors for approval; resources Seth → René |
| 83 | Functional specs complete | 2013-03-26 → 2013-04-02 (+7d) | 2013-03-26 → 2013-04-02 (+7d) |  |  | 21.75d → 18.75d |  |  |
| 84 | Development | 2013-04-01 → 2013-04-03 (+2d) |  | 19d → 17d |  |  |  |  |

## Version 12 (saved 2013-04-03)

Last finish stays 2013-06-14. Complete tasks 27 → 31.

Changed:

| ID | Task | Start | Finish | Duration | Complete | Total float | Predecessors |
| --- | --- | --- | --- | --- | --- | --- | --- |
| 2 | **Upgrade of Existing CSF Apps to CSF 2.0** |  | 2013-04-05 → 2013-04-04 (-1d) | 38d → 37d |  | 50d → 51d |  |
| 10 | **Testing** |  | 2013-04-03 → 2013-04-02 A (-1d) | 31d → 30d | 95% → 100% | 50d → none |  |
| 15 | **BA Testing** |  | 2013-04-03 → 2013-04-02 A (-1d) | 28d → 27d | 93% → 100% | 50d → none |  |
| 17 | IAP (includes planning) |  | 2013-04-03 → 2013-04-02 A (-1d) | 23d → 22d | 91% → 100% | 50d → none |  |
| 24 | **Deployment Preparation** |  | 2013-04-03 → 2013-04-04 (+1d) | 0d → 2d |  | 52d → 51d |  |
| 25 | Get business approval for IAP |  | 2013-04-03 → 2013-04-04 (+1d) | 0d → 2d |  | 52d → 51d |  |
| 26 | **Go-live** |  | 2013-04-05 → 2013-04-04 (-1d) | 27d → 26d |  | 50d → 51d |  |
| 28 | IAP | 2013-04-05 → 2013-04-04 (-1d) | 2013-04-05 → 2013-04-04 (-1d) |  |  | 50d → 51d |  |
| 30 | Upgrade of Existing CSF Apps to CSF 2.0 Complete | 2013-04-05 → 2013-04-04 (-1d) | 2013-04-05 → 2013-04-04 (-1d) |  |  | 50d → 51d |  |
| 40 | **PE REG Upgrade** |  |  |  | 65% → 69% |  |  |
| 41 | **Phase I - Java 6, Touchstone, and CSF Enabling** |  |  |  | 70% → 75% |  |  |
| 46 | **Testing** |  |  |  | 53% → 60% |  |  |
| 48 | QA testing |  | 2013-04-05 → 2013-04-02 A (-3d) | 15d → 12d | 73% → 100% | 34d → none |  |
| 49 | Load testing |  |  |  |  |  | 48FS-2d → 48FS+1d |
| 50 | User testing |  |  |  |  |  | 48 → 48FS+3d |
| 61 | **OREG to Conversion to CSF 2.0** |  |  |  | 45% → 48% |  |  |
| 62 | **Development (including unit testing)** |  | 2013-04-02 A |  | 98% → 100% | 18d → none |  |
| 66 | Phase 4 - Modify OREG to use new JAR and upgrade to CSF 2.0 |  | 2013-04-02 A |  | 93% → 100% | 18d → none |  |
| 67 | OREG conversion development complete | 2013-04-02 A | 2013-04-02 A |  | 0% → 100% | 18d → none |  |
| 68 | Regression Testing |  |  |  | 4% → 13% |  |  |

## Version 13 (saved 2013-04-05)

Last finish stays 2013-06-14.

Added:

| ID | Task | Duration | Start | Finish | Predecessors | Resources |
| --- | --- | --- | --- | --- | --- | --- |
| 35 | Do SAP testing - iteration 1 | 5d | 2013-05-06 | 2013-05-10 | 34 | Frank Q. [25%] |
| 36 | Do SAP testing - iteration 2 | 5d | 2013-05-13 | 2013-05-17 | 35 | Frank Q. [25%] |

Changed:

| ID | Task | Start | Finish | Duration | Complete | Total float | Predecessors | Other |
| --- | --- | --- | --- | --- | --- | --- | --- | --- |
| 31 | **Convert SAIS-Common Apps to CSF 2.0** |  | 2013-05-30 → 2013-05-20 (-10d) | 50d → 41d |  | 11d → 20d |  |  |
| 32 | **Batch Admin** |  | 2013-05-30 → 2013-05-20 (-10d) | 50d → 41d |  | 11d → 20d |  |  |
| 33 | Development |  | 2013-05-01 → 2013-04-26 (-5d) | 28d → 25d |  | 11d → 19d |  |  |
| 34 | Do file comparison | 2013-05-02 → 2013-04-29 (-3d) | 2013-05-30 → 2013-05-03 (-27d) | 21d → 5d |  | 11d → 19d |  | was named Testing; resources none → Steve [25%] |
| 37 | **Deployment Preparation** | 2013-05-16 → 2013-05-06 (-10d) | 2013-05-29 → 2013-05-16 (-13d) | 9.25d → 8.25d |  | 12.75d → 21.75d |  |  |
| 38 | Create deployment plan | 2013-05-16 → 2013-05-06 (-10d) | 2013-05-24 → 2013-05-14 (-10d) |  |  | 13.75d → 21.75d | 34SS+10d → 35SS |  |
| 39 | Review deployment plan with participants | 2013-05-28 → 2013-05-15 (-13d) | 2013-05-28 → 2013-05-15 (-13d) |  |  | 12.75d → 21.75d |  |  |
| 40 | Get business approval | 2013-05-28 → 2013-05-15 (-13d) | 2013-05-29 → 2013-05-16 (-13d) |  |  | 12.75d → 21.75d |  |  |
| 41 | Go-live | 2013-05-30 → 2013-05-20 (-10d) | 2013-05-30 → 2013-05-20 (-10d) |  |  | 11d → 20d |  | constraint none → start no earlier than 2013-05-20 |
| 42 | **PE REG Upgrade** |  |  |  | 69% → 70% |  |  |  |
| 48 | **Testing** |  |  |  | 60% → 61% |  |  |  |
| 51 | Load testing | 2013-04-04 A | 2013-04-04 → 2013-04-05 (+1d) | 1d → 2d | 0% → 50% | 51d → 50d |  |  |

## Version 14 (saved 2013-04-10)

Last finish stays 2013-06-14. Complete tasks 31 → 34.

Changed:

| ID | Task | Start | Finish | Duration | Complete | Total float | Predecessors |
| --- | --- | --- | --- | --- | --- | --- | --- |
| 31 | **Convert SAIS-Common Apps to CSF 2.0** |  |  |  | 0% → 29% |  |  |
| 32 | **Batch Admin** |  |  |  | 0% → 29% |  |  |
| 33 | Development |  |  |  | 0% → 56% |  |  |
| 42 | **PE REG Upgrade** |  |  |  | 70% → 73% |  |  |
| 43 | **Phase I - Java 6, Touchstone, and CSF Enabling** |  |  |  | 75% → 79% |  |  |
| 48 | **Testing** |  |  |  | 61% → 67% | 35d → 34d |  |
| 51 | Load testing |  | 2013-04-05 → 2013-04-10 A (+5d) | 2d → 5d | 50% → 100% | 50d → none |  |
| 52 | User testing | 2013-04-08 → 2013-04-09 (+1d) |  | 15d → 14d |  |  | 50FS+3d → 50FS+4d |
| 63 | **OREG to Conversion to CSF 2.0** |  |  |  | 48% → 53% |  |  |
| 70 | Regression Testing |  |  |  | 13% → 33% |  |  |
| 80 | **Notes Utility Beta** |  |  |  | 29% → 38% |  |  |
| 81 | **Functional Specs** |  | 2013-04-02 A |  | 99% → 100% | 18.75d → none |  |
| 84 | Get sponsor approval on functional spec |  | 2013-04-02 A |  | 95% → 100% | 18.75d → none |  |
| 85 | Functional specs complete | 2013-04-02 A | 2013-04-02 A |  | 0% → 100% | 18.75d → none |  |
| 86 | Development | 2013-04-03 A |  |  | 0% → 35% |  |  |

## Version 15 (saved 2013-04-17)

Last finish stays 2013-06-14. Complete tasks 34 → 35.

Changed:

| ID | Task | Start | Finish | Duration | Complete | Total float |
| --- | --- | --- | --- | --- | --- | --- |
| 2 | **Upgrade of Existing CSF Apps to CSF 2.0** |  | 2013-04-04 → 2013-04-17 (+13d) | 37d → 46d | 97% → 99% | 51d → 42d |
| 24 | **Deployment Preparation** | 2013-04-03 A | 2013-04-04 → 2013-04-17 A (+13d) | 2d → 11d | 0% → 100% | 51d → none |
| 25 | Get business approval for IAP | 2013-04-03 A | 2013-04-04 → 2013-04-17 A (+13d) | 2d → 10d | 0% → 100% | 51d → none |
| 26 | **Go-live** |  | 2013-04-04 → 2013-04-17 (+13d) | 26d → 35d |  | 51d → 42d |
| 28 | IAP | 2013-04-04 → 2013-04-17 (+13d) | 2013-04-04 → 2013-04-17 (+13d) |  |  | 51d → 42d |
| 30 | Upgrade of Existing CSF Apps to CSF 2.0 Complete | 2013-04-04 → 2013-04-17 (+13d) | 2013-04-04 → 2013-04-17 (+13d) |  |  | 51d → 42d |
| 31 | **Convert SAIS-Common Apps to CSF 2.0** |  |  |  | 29% → 37% |  |
| 32 | **Batch Admin** |  |  |  | 29% → 37% |  |
| 33 | Development |  |  |  | 56% → 72% |  |
| 63 | **OREG to Conversion to CSF 2.0** |  |  |  | 53% → 56% |  |
| 70 | Regression Testing |  |  |  | 33% → 50% |  |
| 80 | **Notes Utility Beta** |  |  |  | 38% → 35% |  |
| 86 | Development |  |  |  | 35% → 25% |  |

## Version 16 (saved 2013-04-22)

Last finish stays 2013-06-14. Complete tasks 35 → 37.

Added:

| ID | Task | Duration | Start | Finish | Predecessors | Resources |
| --- | --- | --- | --- | --- | --- | --- |
| 53 | **Deployment Preparation** | 11d? | 2013-04-16 A | 2013-04-30 |  |  |
| 54 | Create deployment plan | 10d | 2013-04-16 A | 2013-04-29 | 52SS | René |
| 55 | Review deployment plan with participants | 1d? | 2013-04-30 | 2013-04-30 | 54 | René |
| 64 | **Deployment Preparation** | 12d | 2013-01-14 | 2013-01-29 |  |  |
| 65 | Create deployment plan | 10d | 2013-01-14 | 2013-01-28 |  | René |
| 66 | Review deployment plan with participants | 1d | 2013-01-29 | 2013-01-29 | 65 | René |

Changed:

| ID | Task | Start | Finish | Duration | Complete | Total float | Predecessors |
| --- | --- | --- | --- | --- | --- | --- | --- |
| 2 | **Upgrade of Existing CSF Apps to CSF 2.0** |  | 2013-04-17 A |  | 99% → 100% | 42d → none |  |
| 26 | **Go-live** |  | 2013-04-17 A |  | 99% → 100% | 42d → none |  |
| 28 | IAP | 2013-04-17 A | 2013-04-17 A |  | 0% → 100% | 42d → none |  |
| 30 | Upgrade of Existing CSF Apps to CSF 2.0 Complete | 2013-04-17 A | 2013-04-17 A |  | 0% → 100% | 42d → none |  |
| 31 | **Convert SAIS-Common Apps to CSF 2.0** |  |  |  | 37% → 44% |  |  |
| 32 | **Batch Admin** |  |  |  | 37% → 44% |  |  |
| 33 | Development |  |  |  | 72% → 84% |  |  |
| 42 | **PE REG Upgrade** |  | 2013-04-29 → 2013-05-06 (+7d) | 76d? → 81d? | 73% → 54% | 34d → 29d |  |
| 43 | **Phase I - Java 6, Touchstone, and CSF Enabling** |  | 2013-04-29 → 2013-05-06 (+7d) | 58d → 63d? | 79% → 64% | 34d → 29d |  |
| 48 | **Testing** |  | 2013-04-26 → 2013-05-03 (+7d) | 48d → 53d | 67% → 60% | 34d → 29d |  |
| 52 | User testing |  | 2013-04-26 → 2013-05-03 (+7d) | 14d → 19d |  | 34d → 29d |  |
| 56 | Go-live | 2013-04-29 → 2013-05-06 (+7d) | 2013-04-29 → 2013-05-06 (+7d) |  |  | 34d → 29d | 52 → 52, 55 |
| 68 | PE REG upgrade complete | 2013-04-29 → 2013-01-29 (-90d) | 2013-04-29 → 2013-01-29 (-90d) |  |  | 34d → 98d | 56, 67 → 63, 66 |
| 69 | **OREG to Conversion to CSF 2.0** |  |  |  | 56% → 59% |  |  |
| 76 | Regression Testing |  |  |  | 50% → 63% |  |  |

## Version 17 (saved 2013-04-23)

Last finish stays 2013-06-14.

Added:

| ID | Task | Duration | Start | Finish | Predecessors | Resources |
| --- | --- | --- | --- | --- | --- | --- |
| 93 | IS&T validate notes | 1d | 2013-04-29 | 2013-04-29 | 92 | René [25%] |

Changed:

| ID | Task | Predecessors |
| --- | --- | --- |
| 94 | UAT | 92 → 93SS |

## Version 18 (saved 2013-04-24)

Last finish stays 2013-06-14. Complete tasks 37 → 39.

Changed:

| ID | Task | Start | Finish | Duration | Complete | Total float |
| --- | --- | --- | --- | --- | --- | --- |
| 42 | **PE REG Upgrade** |  | 2013-05-06 → 2013-04-24 (-12d) | 81d? → 73d? | 54% → 80% | 29d → 37d |
| 43 | **Phase I - Java 6, Touchstone, and CSF Enabling** |  | 2013-05-06 → 2013-04-24 (-12d) | 63d? → 55d? | 64% → 97% | 29d → 37d |
| 48 | **Testing** |  | 2013-05-03 → 2013-04-23 A (-10d) | 53d → 45d | 60% → 100% | 29d → none |
| 52 | User testing | 2013-04-09 A | 2013-05-03 → 2013-04-23 A (-10d) | 19d → 11d | 0% → 100% | 29d → none |
| 53 | **Deployment Preparation** |  | 2013-04-30 → 2013-04-22 (-8d) | 11d? → 5d? | 0% → 80% | 32d → 38d |
| 54 | Create deployment plan |  | 2013-04-29 → 2013-04-19 A (-10d) | 10d → 4d | 0% → 100% | 32d → none |
| 55 | Review deployment plan with participants | 2013-04-30 → 2013-04-22 (-8d) | 2013-04-30 → 2013-04-22 (-8d) |  |  | 32d → 38d |
| 56 | Go-live | 2013-05-06 → 2013-04-24 (-12d) | 2013-05-06 → 2013-04-24 (-12d) |  |  | 29d → 37d |

## Version 19 (saved 2013-05-01)

Last finish stays 2013-06-14. Complete tasks 39 → 42.

Added:

| ID | Task | Duration | Start | Finish |
| --- | --- | --- | --- | --- |
| 42 | Bundle 1 (Advisor Assignment, Instructor Assignment, Supervisor Assignment, and Reg Control List) | 1d? | 2013-01-14 | 2013-01-14 |

Changed:

| ID | Task | Start | Finish | Duration | Complete | Total float | Predecessors |
| --- | --- | --- | --- | --- | --- | --- | --- |
| 31 | **Convert SAIS-Common Apps to CSF 2.0** | 2013-03-22 A → 2013-01-14 A (-67d) |  | 41d → 90d? | 44% → 56% |  |  |
| 32 | **Batch Admin** |  |  |  | 44% → 58% |  |  |
| 33 | Development |  | 2013-04-26 → 2013-04-24 A (-2d) | 25d → 23d | 84% → 100% | 19d → none |  |
| 34 | Do file comparison | 2013-04-29 → 2013-04-25 A (-4d) | 2013-05-03 → 2013-04-26 A (-7d) | 5d → 2d | 0% → 100% | 19d → none |  |
| 35 | Do SAP testing - iteration 1 |  |  |  |  |  | 34 → 34FS+5d |
| 70 | **OREG to Conversion to CSF 2.0** |  |  |  | 59% → 62% |  |  |
| 78 | UAT | 2013-04-29 A |  |  | 0% → 20% | 17d → 18d |  |
| 87 | **Notes Utility Beta** |  |  |  | 35% → 53% |  |  |
| 93 | Development |  | 2013-04-26 → 2013-05-13 (+17d) | 17d → 28d | 25% → 71% | 17d → 24d |  |
| 94 | IS&T validate notes | 2013-04-29 A | 2013-04-29 A |  | 0% → 100% | 17d → none |  |
| 95 | UAT | 2013-04-29 A |  |  | 0% → 20% | 17d → 18d |  |

## Version 20 (saved 2013-05-06)

Last finish stays 2013-06-14. Complete tasks 42 → 44.

Removed: 36 Do SAP testing - iteration 2

Changed:

| ID | Task | Start | Finish | Duration | Complete | Total float | Predecessors | Other |
| --- | --- | --- | --- | --- | --- | --- | --- | --- |
| 31 | **Convert SAIS-Common Apps to CSF 2.0** |  | 2013-05-20 → 2013-05-16 (-4d) | 90d? → 88.25d? | 56% → 77% | 20d → 21.75d |  |  |
| 32 | **Batch Admin** |  | 2013-05-20 → 2013-05-16 (-4d) | 41d → 39.25d | 58% → 79% | 20d → 21.75d |  |  |
| 35 | Do SAP testing - iteration 1 | 2013-05-06 → 2013-05-03 A (-3d) | 2013-05-10 → 2013-05-03 A (-7d) | 5d → 1d | 0% → 100% | 20d → none |  |  |
| 36 | **Deployment Preparation** | 2013-05-06 A | 2013-05-16 → 2013-05-15 (-1d) | 8.25d → 7.25d | 0% → 12% |  |  |  |
| 37 | Get business approval | 2013-05-15 → 2013-05-06 A (-9d) | 2013-05-16 → 2013-05-06 A (-10d) |  | 0% → 100% | 21.75d → none | 39 → 35 |  |
| 38 | Create deployment plan |  |  |  |  |  | 35SS → 35 |  |
| 40 | Go-live | 2013-05-20 → 2013-05-16 (-4d) | 2013-05-20 → 2013-05-16 (-4d) |  |  | 20d → 21.75d | 37, 34 → 35, 39FS+1d | constraint start no earlier than 2013-05-20 → none |
| 86 | **Notes Utility Beta** |  |  |  | 53% → 54% |  |  |  |
| 92 | Development |  | 2013-05-13 → 2013-05-09 (-4d) | 28d → 26d | 71% → 77% | 24d → 26d |  |  |
| 93 | IS&T validate notes on desktop |  |  |  |  |  |  | was named IS&T validate notes |

## Version 21 (saved 2013-05-09)

Last finish stays 2013-06-14.

Changed:

| ID | Task | Start | Finish | Duration | Complete | Total float | Predecessors |
| --- | --- | --- | --- | --- | --- | --- | --- |
| 86 | **Notes Utility Beta** |  |  |  | 54% → 65% |  |  |
| 95 | **Deployment Preparation** | 2013-04-29 A | 2013-05-13 → 2013-05-14 (+1d) | 11d → 12d | 0% → 76% | 24d → 23d |  |
| 96 | Create deployment plan | 2013-04-29 A | 2013-05-03 → 2013-05-10 (+7d) | 5d → 10d | 0% → 90% |  |  |
| 97 | Review deployment plan with participants | 2013-05-06 → 2013-05-13 (+7d) | 2013-05-06 → 2013-05-13 (+7d) |  |  |  |  |
| 98 | Create registration support plan | 2013-05-07 → 2013-05-01 A (-6d) | 2013-05-13 → 2013-05-14 (+1d) | 5d → 10d | 0% → 70% | 24d → 23d | 97 → 96SS+2d |

## Version 22 (saved 2013-05-15)

Last finish stays 2013-06-14. Complete tasks 44 → 50.

Removed: 39 Review deployment plan with participants

Changed:

| ID | Task | Start | Finish | Duration | Complete | Total float | Predecessors |
| --- | --- | --- | --- | --- | --- | --- | --- |
| 31 | **Convert SAIS-Common Apps to CSF 2.0** |  |  | 88.25d? → 89d? | 77% → 97% | 21.75d → 21d |  |
| 32 | **Batch Admin** |  |  | 39.25d → 40d | 79% → 99% | 21.75d → 21d |  |
| 36 | **Deployment Preparation** |  | 2013-05-15 → 2013-05-14 A (-1d) | 7.25d → 7d | 12% → 100% | 21.75d → none |  |
| 38 | Create deployment plan | 2013-05-06 A | 2013-05-14 A |  | 0% → 100% | 21.75d → none |  |
| 39 | Go-live |  |  |  |  | 21.75d → 21d | 35, Review deployment plan with participantsFS+1d → 38FS+2d, 35 |
| 68 | **OREG to Conversion to CSF 2.0** |  |  |  | 62% → 79% |  |  |
| 75 | Regression Testing |  | 2013-05-03 A |  | 63% → 100% | 21d → none |  |
| 76 | UAT |  |  |  | 20% → 87% |  |  |
| 85 | **Notes Utility Beta** |  |  |  | 65% → 87% |  |  |
| 91 | Development |  | 2013-05-09 A |  | 77% → 100% | 26d → none |  |
| 93 | UAT |  |  |  | 20% → 87% |  |  |
| 94 | **Deployment Preparation** |  | 2013-05-14 A |  | 76% → 100% | 23d → none |  |
| 95 | Create deployment plan |  | 2013-05-10 A |  | 90% → 100% | 24d → none |  |
| 96 | Review deployment plan with participants | 2013-05-13 → 2013-05-14 A (+1d) | 2013-05-13 → 2013-05-14 A (+1d) |  | 0% → 100% | 24d → none |  |
| 97 | Create registration support plan |  | 2013-05-14 A |  | 70% → 100% | 23d → none |  |

## Version 23 (saved 2013-05-21)

Last finish 2013-06-14 → 2013-08-01 (+48d). Complete tasks 50 → 51.

Added:

| ID | Task | Duration | Start | Finish | Predecessors | Constraint | Resources |
| --- | --- | --- | --- | --- | --- | --- | --- |
| 41 | **Development** | 27d | 2013-05-28 | 2013-07-03 |  |  |  |
| 42 | Convert Advisor Assignment | 9d | 2013-05-28 | 2013-06-07 |  | start no earlier than 2013-05-28 | Dave [33%] |
| 43 | Convert Supervisor Assignment | 9d | 2013-06-10 | 2013-06-20 | 42 |  | Dave [33%] |
| 44 | Convert Instructor Assignment | 9d | 2013-06-21 | 2013-07-03 | 43 |  | Dave [33%] |
| 45 | Convert Reg Control List | 9d | 2013-05-28 | 2013-06-07 | 42SS |  | Steve [33%] |
| 46 | Bundle 1 development complete | 0d | 2013-07-03 | 2013-07-03 | 44, 45 |  |  |
| 47 | **Testing** | 2d? | 2013-07-04 | 2013-07-05 |  |  |  |
| 48 | Regression Testing | 1d? | 2013-07-04 | 2013-07-04 | 46 |  | Jack [50%] |
| 49 | Load testing | 1d? | 2013-07-05 | 2013-07-05 | 48 |  |  |
| 50 | User Testing | 1d? | 2013-07-05 | 2013-07-05 | 48 |  |  |
| 51 | Testing complete | 0d | 2013-07-05 | 2013-07-05 | 49, 50 |  |  |
| 52 | **Deployment Preparation** | 2d? | 2013-07-08 | 2013-07-09 |  |  |  |
| 53 | Create deployment plan | 1d? | 2013-07-08 | 2013-07-08 | 50 |  |  |
| 54 | Review deployment plan with participants | 1d? | 2013-07-09 | 2013-07-09 | 53 |  |  |
| 69 | **Optimization** | 144d? | 2013-01-14 | 2013-08-01 |  |  |  |
| 70 | Perform analysis/solution design | 20d | 2013-05-13 | 2013-06-07 |  | start no earlier than 2013-05-13 |  |
| 71 | Make coding changes | 10d | 2013-06-10 | 2013-06-21 | 70 |  |  |
| 72 | Do SIT | 15d | 2013-06-24 | 2013-07-12 | 71 |  |  |
| 73 | Do UAT | 14d | 2013-07-15 | 2013-08-01 | 72 |  |  |
| 74 | **Deployment Prepration** | 5d | 2013-07-22 | 2013-07-26 |  |  |  |
| 76 | Go-live | 1d? | 2013-07-29 | 2013-07-29 | 75 |  |  |

Changed:

| ID | Task | Start | Finish | Duration | Complete | Total float | Predecessors |
| --- | --- | --- | --- | --- | --- | --- | --- |
| 31 | **Convert SAIS-Common Apps to CSF 2.0** | 2013-01-14 A → 2013-03-22 A (+67d) | 2013-05-16 → 2013-07-10 (+55d) | 89d? → 79d? | 97% → 45% | 21d → 16d |  |
| 32 | **Batch Admin** |  | 2013-05-16 A |  | 99% → 100% | 21d → none |  |
| 39 | Go-live | 2013-05-16 A | 2013-05-16 A |  | 0% → 100% | 21d → none | 38FS+2d, 35 → 38FS+2d |
| 40 | **Bundle 1 (Advisor Assignment, Instructor Assignment, Supervisor Assignment, and Reg Control List)** | 2013-01-14 → 2013-05-28 (+134d) | 2013-01-14 → 2013-07-10 (+177d) | 1d? → 32d? |  | 109d → 15d |  |
| 55 | Go-live | 2013-04-24 → 2013-07-10 (+77d) | 2013-04-24 → 2013-07-10 (+77d) | 1d → 1d? |  | 37d → 16d | 66, 75 → 51, 54 |
| 56 | **PE REG Upgrade** |  | 2013-04-24 → 2013-08-01 (+99d) | 73d? → 144d? | 80% → 46% | 37d → 0d |  |
| 57 | **Phase I - Java 6, Touchstone, and CSF Enabling** |  | 2013-04-24 → 2013-04-23 A (-1d) | 55d? → 54d | 97% → 100% | 37d → none |  |
| 67 | **Deployment Preparation** |  | 2013-04-22 → 2013-04-19 A (-3d) | 5d? → 4d | 80% → 100% | 38d → none |  |
| 75 | Review deployment plan with participants | 2013-04-22 → 2013-07-22 (+91d) | 2013-04-22 → 2013-07-26 (+95d) | 1d? → 5d |  | 38d → 3d | 68 → 73SS+5d |

## Version 24 (saved 2013-06-11)

Last finish 2013-08-01 → 2013-08-06 (+5d). Complete tasks 51 → 64.

Added:

| ID | Task | Duration | Start | Finish | Predecessors | Resources |
| --- | --- | --- | --- | --- | --- | --- |
| 49 | Test Advisor Assignment | 10d | 2013-06-11 | 2013-06-24 | 42FS+1d | Jack |
| 50 | Test Instructor Assignment | 10d | 2013-07-05 | 2013-07-18 | 49, 44 | Jack |
| 51 | Test Supervisor Assignment | 12d | 2013-07-19 | 2013-08-05 | 50, 43 | Jack |
| 52 | Test Reg Control List | 1d? | 2013-06-10 | 2013-06-10 | 45 | Leo [25%] |
| 53 | Regression testing complete | 0d | 2013-08-05 | 2013-08-05 | 52, 49, 50, 51 |  |
| 55 | Test Advisor Assignment | 1d? | 2013-01-14 | 2013-01-14 |  |  |
| 56 | Test Instructor Assignment | 1d? | 2013-01-15 | 2013-01-15 | 55 |  |
| 57 | Test Supervisor Assignment | 1d? | 2013-01-16 | 2013-01-16 | 56 |  |
| 58 | Test Reg Control List | 1d? | 2013-01-17 | 2013-01-17 | 57 |  |
| 59 | User Testing Complete | 0d | 2013-01-17 | 2013-01-17 | 55, 56, 57, 58 |  |

Removed: 49 Load testing

Changed:

| ID | Task | Start | Finish | Duration | Complete | Total float | Predecessors | Other |
| --- | --- | --- | --- | --- | --- | --- | --- | --- |
| 31 | **Convert SAIS-Common Apps to CSF 2.0** | 2013-03-22 A → 2013-01-14 A (-67d) | 2013-07-10 → 2013-08-06 (+27d) | 79d? → 147d? | 45% → 49% | 16d → 0d |  |  |
| 40 | **Bundle 1 (Advisor Assignment, Instructor Assignment, Supervisor Assignment, and Reg Control List)** | 2013-05-28 → 2013-01-14 A (-134d) | 2013-07-10 → 2013-08-06 (+27d) | 32d? → 147d? | 0% → 26% | 15d → 0d |  |  |
| 41 | **Development** | 2013-05-28 A |  |  | 0% → 56% | 15d → 24d |  |  |
| 42 | Convert Advisor Assignment | 2013-05-28 A | 2013-06-07 A |  | 0% → 100% | 15d → none |  |  |
| 43 | Convert Supervisor Assignment | 2013-06-10 A |  |  | 0% → 22% | 15d → 0d |  |  |
| 45 | Convert Reg Control List | 2013-05-28 A | 2013-06-07 A |  | 0% → 100% | 18d → none |  |  |
| 46 | Bundle 1 development complete |  |  |  |  |  | 44, 45 → 44, 45, 42, 43 |  |
| 47 | **Testing** | 2013-07-04 → 2013-01-14 (-171d) | 2013-07-05 → 2013-08-05 (+31d) | 2d? → 146d? |  | 16d → 0d |  |  |
| 48 | **Regression Testing** | 2013-07-04 → 2013-06-10 (-24d) | 2013-07-04 → 2013-08-05 (+32d) | 1d? → 41d? |  | 16d → 0d | 46 → none | resources Jack [50%] → none |
| 54 | **User Testing** | 2013-07-05 → 2013-01-14 (-172d) | 2013-07-05 → 2013-01-17 (-169d) | 1d? → 4d? |  | 16d → 140d | 48 → none |  |
| 60 | Testing complete | 2013-07-05 → 2013-08-05 (+31d) | 2013-07-05 → 2013-08-05 (+31d) |  |  | 2d → 0d | Load testing, 54 → 53, 59 |  |
| 61 | **Deployment Preparation** | 2013-07-08 → 2013-01-18 (-171d) | 2013-07-09 → 2013-01-21 (-169d) |  |  | 16d → 140d |  |  |
| 62 | Create deployment plan | 2013-07-08 → 2013-01-18 (-171d) | 2013-07-08 → 2013-01-18 (-171d) |  |  | 16d → 140d |  |  |
| 63 | Review deployment plan with participants | 2013-07-09 → 2013-01-21 (-169d) | 2013-07-09 → 2013-01-21 (-169d) |  |  | 16d → 140d |  |  |
| 64 | Go-live | 2013-07-10 → 2013-08-06 (+27d) | 2013-07-10 → 2013-08-06 (+27d) |  |  | 16d → 0d |  |  |
| 65 | **PE REG Upgrade** |  | 2013-08-01 → 2013-08-02 (+1d) | 144d? → 145d? |  | 0d → 2d |  |  |
| 78 | **Optimization** |  | 2013-08-01 → 2013-08-02 (+1d) | 144d? → 145d? |  | 0d → 2d |  |  |
| 85 | Go-live | 2013-07-29 → 2013-08-02 (+4d) | 2013-07-29 → 2013-08-02 (+4d) |  |  | 3d → 2d | 84 → 84, 82 |  |
| 98 | **OREG to Conversion to CSF 2.0** |  |  |  | 79% → 97% | 34d → 37d |  |  |
| 106 | UAT |  | 2013-05-17 A |  | 87% → 100% | 52d → none |  |  |
| 107 | **Deployment Preparation** | 2013-04-29 A | 2013-05-13 A |  | 0% → 100% | 58d → none |  |  |
| 108 | Create deployment plan | 2013-04-29 A | 2013-05-03 A |  | 0% → 100% | 58d → none |  |  |
| 109 | Review deployment plan with participants | 2013-05-06 A | 2013-05-06 A |  | 0% → 100% | 58d → none |  |  |
| 110 | Create registration support plan | 2013-05-07 A | 2013-05-13 A |  | 0% → 100% | 58d → none |  |  |
| 111 | Go-live | 2013-05-21 A | 2013-05-21 A |  | 0% → 100% | 52d → none |  |  |
| 112 | Prod smoke test | 2013-05-21 A | 2013-05-21 A |  | 0% → 100% | 52d → none |  |  |
| 113 | Registration opens | 2013-06-03 A | 2013-06-03 A |  | 0% → 100% | 34d → none |  |  |
| 114 | Registration support | 2013-06-03 A |  |  | 0% → 70% | 34d → 37d |  |  |
| 115 | **Notes Utility Beta** |  |  |  | 87% → 97% | 34d → 37d |  |  |
| 123 | UAT |  | 2013-05-17 A |  | 87% → 100% | 52d → none |  |  |
| 128 | Go-live | 2013-05-21 A | 2013-05-21 A |  | 0% → 100% | 52d → none |  |  |
| 129 | Prod smoke test | 2013-05-21 A | 2013-05-21 A |  | 0% → 100% | 52d → none |  |  |
| 130 | Registration opens | 2013-06-03 A | 2013-06-03 A |  | 0% → 100% | 34d → none |  |  |
| 131 | Registration support | 2013-06-03 A |  |  | 0% → 70% | 34d → 37d |  |  |

## Version 25 (saved 2013-06-19)

Last finish stays 2013-08-06. Complete tasks 64 → 66.

Changed:

| ID | Task | Start | Finish | Complete | Total float |
| --- | --- | --- | --- | --- | --- |
| 31 | **Convert SAIS-Common Apps to CSF 2.0** |  |  | 49% → 55% |  |
| 40 | **Bundle 1 (Advisor Assignment, Instructor Assignment, Supervisor Assignment, and Reg Control List)** |  |  | 26% → 36% |  |
| 47 | **Testing** | 2013-01-14 A |  | 0% → 19% |  |
| 48 | **Regression Testing** | 2013-06-10 A |  | 0% → 21% |  |
| 49 | Test Advisor Assignment | 2013-06-11 A |  | 0% → 70% |  |
| 98 | **OREG to Conversion to CSF 2.0** |  | 2013-06-14 A | 97% → 100% | 37d → none |
| 114 | Registration support |  | 2013-06-14 A | 70% → 100% | 37d → none |
| 115 | **Notes Utility Beta** |  | 2013-06-14 A | 97% → 100% | 37d → none |
| 131 | Registration support |  | 2013-06-14 A | 70% → 100% | 37d → none |

## Version 26 (saved 2013-07-01)

Last finish stays 2013-08-06. Complete tasks 66 → 70.

Changed:

| ID | Task | Start | Finish | Duration | Complete | Total float |
| --- | --- | --- | --- | --- | --- | --- |
| 31 | **Convert SAIS-Common Apps to CSF 2.0** |  |  |  | 55% → 71% |  |
| 40 | **Bundle 1 (Advisor Assignment, Instructor Assignment, Supervisor Assignment, and Reg Control List)** |  |  |  | 36% → 58% |  |
| 41 | **Development** |  |  |  | 56% → 94% | 24d → 16d |
| 43 | Convert Supervisor Assignment |  | 2013-06-20 A |  | 22% → 100% | 0d → none |
| 44 | Convert Instructor Assignment | 2013-06-21 A |  |  | 0% → 78% |  |
| 47 | **Testing** |  |  |  | 19% → 27% |  |
| 48 | **Regression Testing** |  |  |  | 21% → 30% |  |
| 49 | Test Advisor Assignment |  | 2013-06-24 A |  | 70% → 100% | 7d → none |
| 65 | **PE REG Upgrade** |  | 2013-08-02 → 2013-07-26 (-7d) | 145d? → 140d? | 46% → 72% | 2d → 7d |
| 78 | **Optimization** | 2013-01-14 → 2013-05-13 A (+119d) | 2013-08-02 → 2013-07-26 (-7d) | 145d? → 55d? | 0% → 58% | 2d → 7d |
| 79 | Perform analysis/solution design | 2013-05-13 A | 2013-06-07 → 2013-06-21 A (+14d) | 20d → 30d | 0% → 100% | 2d → none |
| 80 | Make coding changes | 2013-06-10 → 2013-06-24 A (+14d) | 2013-06-21 → 2013-06-28 A (+7d) | 10d → 5d | 0% → 100% | 2d → none |
| 81 | Do SIT | 2013-06-24 → 2013-07-01 (+7d) | 2013-07-12 → 2013-07-05 (-7d) | 15d → 5d |  | 2d → 7d |
| 82 | Do UAT | 2013-07-15 → 2013-07-08 (-7d) | 2013-08-01 → 2013-07-25 (-7d) |  |  | 2d → 7d |
| 83 | **Deployment Prepration** | 2013-07-22 → 2013-07-15 (-7d) | 2013-07-26 → 2013-07-19 (-7d) |  |  | 6d → 11d |
| 84 | Review deployment plan with participants | 2013-07-22 → 2013-07-15 (-7d) | 2013-07-26 → 2013-07-19 (-7d) |  |  | 6d → 11d |
| 85 | Go-live | 2013-08-02 → 2013-07-26 (-7d) | 2013-08-02 → 2013-07-26 (-7d) |  |  | 2d → 7d |

## Version 27 (saved 2013-07-15)

Last finish stays 2013-08-06. Complete tasks 70 → 73.

Changed:

| ID | Task | Start | Finish | Duration | Complete | Total float | Predecessors |
| --- | --- | --- | --- | --- | --- | --- | --- |
| 31 | **Convert SAIS-Common Apps to CSF 2.0** |  |  |  | 71% → 73% |  |  |
| 40 | **Bundle 1 (Advisor Assignment, Instructor Assignment, Supervisor Assignment, and Reg Control List)** |  |  |  | 58% → 61% |  |  |
| 41 | **Development** |  | 2013-07-03 A |  | 94% → 100% | 16d → none |  |
| 44 | Convert Instructor Assignment |  | 2013-07-03 A |  | 78% → 100% | 0d → none |  |
| 46 | Bundle 1 development complete | 2013-07-03 A | 2013-07-03 A |  | 0% → 100% | 16d → none |  |
| 65 | **PE REG Upgrade** |  | 2013-07-26 → 2013-07-31 (+5d) | 140d? → 143d? | 72% → 77% | 7d → 4d |  |
| 78 | **Optimization** |  | 2013-07-26 → 2013-07-31 (+5d) | 55d? → 58d? | 58% → 70% | 7d → 4d |  |
| 81 | Do SIT | 2013-07-01 → 2013-07-08 A (+7d) | 2013-07-05 → 2013-07-09 A (+4d) | 5d → 2d | 0% → 100% | 7d → none |  |
| 82 | Do UAT | 2013-07-08 → 2013-07-17 (+9d) | 2013-07-25 → 2013-07-30 (+5d) | 14d → 10d |  | 7d → 4d | 81 → 81FS+5d |
| 83 | **Deployment Prepration** | 2013-07-15 → 2013-07-24 (+9d) | 2013-07-19 → 2013-07-30 (+11d) |  |  | 11d → 4d |  |
| 84 | Review deployment plan with participants | 2013-07-15 → 2013-07-24 (+9d) | 2013-07-19 → 2013-07-30 (+11d) |  |  | 11d → 4d |  |
| 85 | Go-live | 2013-07-26 → 2013-07-31 (+5d) | 2013-07-26 → 2013-07-31 (+5d) |  |  | 7d → 4d |  |

## Version 28 (saved 2013-07-31)

Last finish 2013-08-06 → 2013-10-31 (+86d).

Added:

| ID | Task | Duration | Start | Finish | Predecessors | Constraint | Resources |
| --- | --- | --- | --- | --- | --- | --- | --- |
| 88 | Update applicationContext files and reorganize | 1d | 2013-08-19 | 2013-08-19 |  | start no earlier than 2013-08-19 | Ram |
| 89 | Make changes to DAO modules (21 modules) | 12d | 2013-08-20 | 2013-09-05 | 88 |  | Ram |
| 90 | Fix service modules unit tests and create new unit tests for DAO | 18d | 2013-09-06 | 2013-10-01 | 89 |  | Ram |
| 91 | Replace sfbreCurrentPerson domain object and related objects and mappings | 4d | 2013-10-02 | 2013-10-07 | 90 |  | Ram |

Removed: 89 Unit test changes

Changed:

| ID | Task | Start | Finish | Duration | Complete | Total float | Predecessors | Other |
| --- | --- | --- | --- | --- | --- | --- | --- | --- |
| 65 | **PE REG Upgrade** |  | 2013-07-31 → 2013-10-31 (+92d) | 143d? → 209d? | 77% → 62% | 4d → 0d |  |  |
| 66 | **Phase I - Java 6, Touchstone, and CSF Enabling** |  | 2013-04-23 A → 2013-04-23 |  | 100% → 84% | none → 137d |  |  |
| 71 | **Testing** |  | 2013-04-23 A → 2013-04-23 |  | 100% → 73% | none → 137d |  |  |
| 75 | User testing | 2013-04-09 A → 2013-04-09 | 2013-04-23 A → 2013-04-23 |  | 100% → 0% | none → 137d |  | resources none → Carrie |
| 78 | **Optimization** |  | 2013-07-31 → 2013-08-08 (+8d) | 58d? → 63.5d | 70% → 95% | 4d → 60.5d |  |  |
| 82 | Do UAT | 2013-07-17 A | 2013-07-30 → 2013-08-08 (+9d) |  | 0% → 75% | 4d → 60.5d |  |  |
| 83 | **Deployment Prepration** | 2013-07-24 A | 2013-07-30 → 2013-07-31 A (+1d) | 5d → 6d | 0% → 100% | 4d → none |  |  |
| 84 | Review deployment plan with participants | 2013-07-24 A | 2013-07-30 → 2013-07-31 A (+1d) | 5d → 6d | 0% → 100% | 4d → none |  |  |
| 85 | Go-live | 2013-07-31 → 2013-08-08 (+8d) | 2013-07-31 → 2013-08-08 (+8d) | 1d? → 0d |  | 4d → 60.5d |  |  |
| 86 | **Phase II - Full CSF Upgrade** |  | 2013-03-19 → 2013-10-31 (+226d) | 47d? → 209d? |  | 100d → 0d |  |  |
| 87 | **Development** | 2013-03-18 → 2013-08-19 (+154d) | 2013-03-19 → 2013-10-15 (+210d) | 2d? → 42d |  | 100d → 0d |  |  |
| 92 | Rewrite the email codes to use the new csf email service | 2013-03-18 → 2013-10-08 (+204d) | 2013-03-18 → 2013-10-15 (+211d) | 1d? → 5d |  | 100d → 0d | 70 → 70, 91 | was named Perform full upgrade |
| 93 | **Testing** | 2013-01-14 → 2013-10-16 (+275d) | 2013-01-14 → 2013-10-17 (+276d) | 1d? → 2d? |  | 146d → 0d |  |  |
| 94 | QA | 2013-01-14 → 2013-10-16 (+275d) | 2013-01-14 → 2013-10-16 (+275d) |  |  | 146d → 0d | none → 92 | resources none → Jack |
| 95 | User | 2013-01-14 → 2013-10-17 (+276d) | 2013-01-14 → 2013-10-17 (+276d) |  |  | 146d → 10d | none → 94 | resources none → Carrie |
| 96 | **Deployment Preparation** | 2013-01-14 → 2013-10-17 (+276d) | 2013-01-29 → 2013-10-31 (+275d) | 12d → 11d |  | 135d → 0d |  |  |
| 97 | Create deployment plan | 2013-01-14 → 2013-10-17 (+276d) | 2013-01-28 → 2013-10-30 (+275d) |  |  | 135d → 0d | none → 94 |  |
| 98 | Review deployment plan with participants | 2013-01-29 → 2013-10-31 (+275d) | 2013-01-29 → 2013-10-31 (+275d) |  |  | 135d → 0d |  |  |
| 100 | PE REG upgrade complete | 2013-01-29 → 2013-10-31 (+275d) | 2013-01-29 → 2013-10-31 (+275d) |  |  | 135d → 0d |  |  |

## Version 29 (saved 2013-08-09)

Last finish stays 2013-10-31. Complete tasks 73 → 75.

Changed:

| ID | Task | Start | Finish | Duration | Complete | Total float |
| --- | --- | --- | --- | --- | --- | --- |
| 65 | **PE REG Upgrade** |  |  |  | 62% → 68% |  |
| 66 | **Phase I - Java 6, Touchstone, and CSF Enabling** |  | 2013-04-23 A |  | 84% → 100% | 137d → none |
| 71 | **Testing** |  | 2013-04-23 A |  | 73% → 100% | 137d → none |
| 75 | User testing | 2013-04-09 A | 2013-04-23 A |  | 0% → 100% | 137d → none |
| 78 | **Optimization** |  | 2013-08-08 → 2013-08-09 (+1d) | 63.5d → 65d |  | 60.5d → 59d |
| 85 | Go-live | 2013-08-08 → 2013-08-09 A (+1d) | 2013-08-08 → 2013-08-09 A (+1d) |  | 0% → 100% | 60.5d → none |

## Version 30 (saved 2013-08-27)

Last finish 2013-10-31 → 2013-11-15 (+15d). Complete tasks 75 → 77.

Added:

| ID | Task | Duration | Start | Finish | Predecessors | Constraint | Resources |
| --- | --- | --- | --- | --- | --- | --- | --- |
| 65 | Deploy Instructor and Supervisor Assignment | 1d? | 2013-11-14 | 2013-11-14 | 56, 57 |  |  |
| 66 | Deploy Reg Control List | 1d? | 2013-07-10 | 2013-07-10 | 58 |  |  |
| 67 | Deploy Advisor Assignment | 1d? | 2013-09-24 | 2013-09-24 | 55 |  |  |
| 68 | Deployments complete | 1d? | 2013-01-14 | 2013-01-14 |  |  |  |
| 92 | Ramp up | 3d | 2013-08-21 A | 2013-08-23 A |  | start no earlier than 2013-08-21 | Ram |
| 98 | Development complete | 0d | 2013-10-22 | 2013-10-22 | 97 |  | Ram |
| 100 | Do test planning | 1d? | 2013-10-23 | 2013-10-23 | 98 |  |  |

Changed:

| ID | Task | Start | Finish | Duration | Complete | Total float | Predecessors | Other |
| --- | --- | --- | --- | --- | --- | --- | --- | --- |
| 31 | **Convert SAIS-Common Apps to CSF 2.0** |  | 2013-08-06 → 2013-11-15 (+101d) | 147d? → 220d? | 73% → 42% | 62d → 0d |  |  |
| 40 | **Bundle 1 (Advisor Assignment, Instructor Assignment, Supervisor Assignment, and Reg Control List)** |  | 2013-08-06 → 2013-11-15 (+101d) | 147d? → 220d? | 61% → 29% | 62d → 0d |  |  |
| 47 | **Testing** | 2013-01-14 A → 2013-06-10 A (+147d) | 2013-08-05 → 2013-11-13 (+100d) | 146d? → 113d? | 27% → 9% | 62d → 2d |  |  |
| 48 | **Regression Testing** |  | 2013-08-05 → 2013-10-29 (+85d) | 41d? → 102d? | 30% → 18% | 62d → 13d |  |  |
| 49 | Test Advisor Assignment |  |  |  |  |  |  | resources Jack → Jack [50%] |
| 50 | Test Instructor Assignment | 2013-07-05 → 2013-08-27 (+53d) | 2013-07-18 → 2013-09-24 (+68d) | 10d → 20d |  | 61d → 0d |  | constraint none → start no earlier than 2013-08-27; resources Jack → Jack [50%] |
| 51 | Test Supervisor Assignment | 2013-07-19 → 2013-09-25 (+68d) | 2013-08-05 → 2013-10-29 (+85d) | 12d → 24d |  | 62d → 0d |  | resources Jack → Jack [50%] |
| 53 | Regression testing complete | 2013-08-05 → 2013-10-29 (+85d) | 2013-08-05 → 2013-10-29 (+85d) |  |  | 1.5d → 13d |  |  |
| 54 | **User Testing** | 2013-01-14 → 2013-06-11 (+148d) | 2013-01-17 → 2013-11-13 (+300d) | 4d? → 112d |  | 202d → 0d |  |  |
| 55 | Test Advisor Assignment | 2013-01-14 → 2013-08-27 (+225d) | 2013-01-14 → 2013-09-23 (+252d) | 1d? → 19d |  | 202d → 14d | none → 49 | constraint none → start no earlier than 2013-08-27; resources none → Brian |
| 56 | Test Instructor Assignment | 2013-01-15 → 2013-09-25 (+253d) | 2013-01-15 → 2013-10-08 (+266d) | 1d? → 10d |  | 140d → 15d | 55 → 50, 55 | resources none → Brian |
| 57 | Test Supervisor Assignment | 2013-01-16 → 2013-10-30 (+287d) | 2013-01-16 → 2013-11-13 (+301d) | 1d? → 10d |  | 140d → 0d | 56 → 51, 56 | resources none → Brian |
| 58 | Test Reg Control List | 2013-01-17 → 2013-06-11 (+145d) | 2013-01-17 → 2013-07-09 (+173d) | 1d? → 20d |  | 140d → 90d | 57 → 52 | resources none → Roberta |
| 59 | User Testing Complete | 2013-01-17 → 2013-11-13 (+300d) | 2013-01-17 → 2013-11-13 (+300d) |  |  | 202d → 0d |  | resources none → Brian |
| 60 | Testing complete | 2013-08-05 → 2013-11-13 (+100d) | 2013-08-05 → 2013-11-13 (+100d) |  |  | 1.5d → 2d |  |  |
| 61 | **Deployment Preparation** | 2013-01-18 → 2013-11-14 (+300d) | 2013-01-21 → 2013-11-15 (+298d) |  |  | 202d → 0d |  |  |
| 62 | Create deployment plan | 2013-01-18 → 2013-11-14 (+300d) | 2013-01-18 → 2013-11-14 (+300d) |  |  | 140d → 0d |  |  |
| 63 | Review deployment plan with participants | 2013-01-21 → 2013-11-15 (+298d) | 2013-01-21 → 2013-11-15 (+298d) |  |  | 140d → 0d |  |  |
| 64 | **Deployments** | 2013-08-06 → 2013-01-14 (-204d) | 2013-08-06 → 2013-11-14 (+100d) | 1d? → 219d? |  | 62d → 1d | 60, 63 → none | was named Go-live |
| 69 | **PE REG Upgrade** |  | 2013-10-31 → 2013-11-08 (+8d) | 209d? → 215d? | 68% → 70% | 0d → 5d |  |  |
| 82 | **Optimization** |  | 2013-08-09 A |  | 95% → 100% | 59d → none |  |  |
| 86 | Do UAT |  | 2013-08-08 A |  | 75% → 100% | 60.5d → none |  |  |
| 90 | **Phase II - Full CSF Upgrade** | 2013-01-14 A | 2013-10-31 → 2013-11-08 (+8d) | 209d? → 215d? | 0% → 5% | 0d → 5d |  |  |
| 91 | **Development** | 2013-08-19 → 2013-08-21 A (+2d) | 2013-10-15 → 2013-10-22 (+7d) | 42d → 45d | 0% → 7% | 0d → 4d |  |  |
| 93 | Update applicationContext files and reorganize | 2013-08-19 → 2013-08-26 (+7d) | 2013-08-19 → 2013-08-26 (+7d) |  |  | 0d → 4d | none → 92 | constraint start no earlier than 2013-08-19 → none |
| 94 | Make changes to DAO modules (21 modules) | 2013-08-20 → 2013-08-27 (+7d) | 2013-09-05 → 2013-09-12 (+7d) |  |  | 0d → 4d |  |  |
| 95 | Fix service modules unit tests and create new unit tests for DAO | 2013-09-06 → 2013-09-13 (+7d) | 2013-10-01 → 2013-10-08 (+7d) |  |  | 0d → 4d |  |  |
| 96 | Replace sfbreCurrentPerson domain object and related objects and mappings | 2013-10-02 → 2013-10-09 (+7d) | 2013-10-07 → 2013-10-15 (+8d) |  |  | 0d → 4d |  |  |
| 97 | Rewrite the email codes to use the new csf email service | 2013-10-08 → 2013-10-16 (+8d) | 2013-10-15 → 2013-10-22 (+7d) |  |  | 0d → 4d |  |  |
| 99 | **Testing** | 2013-10-16 → 2013-10-23 (+7d) | 2013-10-17 → 2013-10-25 (+8d) | 2d? → 3d? |  | 0d → 4d |  |  |
| 101 | Execute regression test | 2013-10-16 → 2013-10-24 (+8d) | 2013-10-16 → 2013-10-24 (+8d) |  |  | 0d → 4d | 97 → 100 | was named QA |
| 102 | Perform user test | 2013-10-17 → 2013-10-25 (+8d) | 2013-10-17 → 2013-10-25 (+8d) |  |  | 10d → 15d |  | was named User |
| 103 | **Deployment Preparation** | 2013-10-17 → 2013-10-25 (+8d) | 2013-10-31 → 2013-11-08 (+8d) |  |  | 0d → 4d |  |  |
| 104 | Create deployment plan | 2013-10-17 → 2013-10-25 (+8d) | 2013-10-30 → 2013-11-07 (+8d) |  |  | 0d → 4d |  |  |
| 105 | Review deployment plan with participants | 2013-10-31 → 2013-11-08 (+8d) | 2013-10-31 → 2013-11-08 (+8d) |  |  | 0d → 5d |  |  |
| 107 | PE REG upgrade complete | 2013-10-31 → 2013-11-08 (+8d) | 2013-10-31 → 2013-11-08 (+8d) |  |  | 0d → 4d |  |  |

## Version 31 (saved 2013-08-28)

Last finish 2013-11-15 → 2013-11-18 (+3d).

Added:

| ID | Task | Duration | Start | Finish | Predecessors |
| --- | --- | --- | --- | --- | --- |
| 103 | Perform load test | 1d? | 2013-10-28 | 2013-10-28 | 102 |

Changed:

| ID | Task | Start | Finish | Duration | Complete | Total float | Other |
| --- | --- | --- | --- | --- | --- | --- | --- |
| 31 | **Convert SAIS-Common Apps to CSF 2.0** |  | 2013-11-15 → 2013-11-18 (+3d) | 220d? → 221d? |  |  |  |
| 40 | **Bundle 1 (Advisor Assignment, Instructor Assignment, Supervisor Assignment, and Reg Control List)** |  | 2013-11-15 → 2013-11-18 (+3d) | 220d? → 221d? |  |  |  |
| 47 | **Testing** |  | 2013-11-13 → 2013-11-14 (+1d) | 113d? → 114d? |  |  |  |
| 48 | **Regression Testing** |  | 2013-10-29 → 2013-10-30 (+1d) | 102d? → 103d? |  |  |  |
| 50 | Test Instructor Assignment | 2013-08-27 → 2013-08-28 (+1d) | 2013-09-24 → 2013-09-25 (+1d) |  |  |  | constraint start no earlier than 2013-08-27 → start no earlier than 2013-08-28 |
| 51 | Test Supervisor Assignment | 2013-09-25 → 2013-09-26 (+1d) | 2013-10-29 → 2013-10-30 (+1d) |  |  |  |  |
| 53 | Regression testing complete | 2013-10-29 → 2013-10-30 (+1d) | 2013-10-29 → 2013-10-30 (+1d) |  |  |  |  |
| 54 | **User Testing** |  | 2013-11-13 → 2013-11-14 (+1d) | 112d → 113d |  |  |  |
| 56 | Test Instructor Assignment | 2013-09-25 → 2013-09-26 (+1d) | 2013-10-08 → 2013-10-09 (+1d) |  |  |  |  |
| 57 | Test Supervisor Assignment | 2013-10-30 → 2013-10-31 (+1d) | 2013-11-13 → 2013-11-14 (+1d) |  |  |  |  |
| 59 | User Testing Complete | 2013-11-13 → 2013-11-14 (+1d) | 2013-11-13 → 2013-11-14 (+1d) |  |  |  |  |
| 60 | Testing complete | 2013-11-13 → 2013-11-14 (+1d) | 2013-11-13 → 2013-11-14 (+1d) |  |  |  |  |
| 61 | **Deployment Preparation** | 2013-11-14 → 2013-11-15 (+1d) | 2013-11-15 → 2013-11-18 (+3d) |  |  |  |  |
| 62 | Create deployment plan | 2013-11-14 → 2013-11-15 (+1d) | 2013-11-14 → 2013-11-15 (+1d) |  |  |  |  |
| 63 | Review deployment plan with participants | 2013-11-15 → 2013-11-18 (+3d) | 2013-11-15 → 2013-11-18 (+3d) |  |  |  |  |
| 64 | **Deployments** |  | 2013-11-14 → 2013-11-15 (+1d) | 219d? → 220d? |  |  |  |
| 65 | Deploy Instructor and Supervisor Assignment | 2013-11-14 → 2013-11-15 (+1d) | 2013-11-14 → 2013-11-15 (+1d) |  |  |  |  |
| 69 | **PE REG Upgrade** |  |  |  | 70% → 69% | 5d → 6d |  |
| 99 | **Testing** |  | 2013-10-25 → 2013-10-28 (+3d) | 3d? → 4d? |  | 4d → 5d |  |

## Version 32 (saved 2013-08-29)

Last finish stays 2013-11-18.

Changed:

| ID | Task | Start | Finish | Duration | Total float | Other |
| --- | --- | --- | --- | --- | --- | --- |
| 47 | **Testing** | 2013-06-10 A → 2013-06-11 A (+1d) |  | 114d? → 113d |  |  |
| 48 | **Regression Testing** | 2013-06-10 A → 2013-06-11 A (+1d) |  | 103d? → 102d |  |  |
| 52 | Test Reg Control List | 2013-06-10 → 2013-09-03 (+85d) | 2013-06-10 → 2013-09-04 (+86d) | 1d? → 2d | 89d → 28d | constraint none → start no earlier than 2013-09-02; resources Leo [25%] → Roberta [50%] |
| 54 | **User Testing** | 2013-06-11 → 2013-08-27 (+77d) |  | 113d → 58d |  |  |
| 58 | Test Reg Control List | 2013-06-11 → 2013-09-05 (+86d) | 2013-07-09 → 2013-10-02 (+85d) |  | 90d → 29d | resources Roberta → Brian |
| 66 | Deploy Reg Control List | 2013-07-10 → 2013-10-03 (+85d) | 2013-07-10 → 2013-10-03 (+85d) |  | 91d → 30d |  |

## Version 33 (saved 2013-09-04)

Last finish 2013-11-18 → 2013-12-16 (+28d).

Changed:

| ID | Task | Start | Finish | Duration | Complete | Total float | Predecessors | Other |
| --- | --- | --- | --- | --- | --- | --- | --- | --- |
| 69 | **PE REG Upgrade** |  | 2013-11-08 → 2013-12-16 (+38d) | 215d? → 241d? | 69% → 61% | 6d → 0d |  |  |
| 90 | **Phase II - Full CSF Upgrade** |  | 2013-11-08 → 2013-12-16 (+38d) | 215d? → 241d? | 5% → 4% | 6d → 0d |  |  |
| 99 | **Testing** |  | 2013-10-28 → 2013-12-03 (+36d) | 4d? → 30d? |  | 5d → 0d |  |  |
| 100 | Do test planning |  | 2013-10-23 → 2013-10-24 (+1d) | 1d? → 2d |  | 4d → 0d |  | resources none → Jack [50%] |
| 101 | Execute regression test | 2013-10-24 → 2013-10-25 (+1d) | 2013-10-24 → 2013-11-27 (+34d) | 1d? → 23d |  | 5d → 0d |  | resources Jack → Jack [50%] |
| 102 | Perform user test | 2013-10-25 → 2013-12-02 (+38d) | 2013-10-25 → 2013-12-02 (+38d) |  |  | 15d → 9d |  |  |
| 103 | Perform load test | 2013-10-28 → 2013-12-03 (+36d) | 2013-10-28 → 2013-12-03 (+36d) |  |  | 15d → 9d |  | resources none → Steve |
| 104 | **Deployment Preparation** | 2013-10-25 → 2013-12-02 (+38d) | 2013-11-08 → 2013-12-16 (+38d) |  |  | 5d → 0d |  |  |
| 105 | Create deployment plan | 2013-10-25 → 2013-12-02 (+38d) | 2013-11-07 → 2013-12-13 (+36d) |  |  | 5d → 0d |  |  |
| 106 | Review deployment plan with participants | 2013-11-08 → 2013-12-16 (+38d) | 2013-11-08 → 2013-12-16 (+38d) |  |  | 6d → 0d |  |  |
| 108 | PE REG upgrade complete | 2013-11-08 → 2013-01-14 (-298d) | 2013-11-08 → 2013-01-14 (-298d) |  |  | 6d → 240d | 102, 106 → 107 |  |

## Version 34 (saved 2013-09-09)

Last finish stays 2013-12-16.

Changed:

| ID | Task | Other |
| --- | --- | --- |
| 31 | **Convert SAIS-Common Apps to CSF 2.0** | baseline start none → 2013-06-11; baseline finish none → 2013-10-30 |
| 40 | **Bundle 1 (Advisor Assignment, Instructor Assignment, Supervisor Assignment, and Reg Control List)** | baseline start none → 2013-06-11; baseline finish none → 2013-10-30 |
| 47 | **Testing** | baseline start none → 2013-06-11; baseline finish none → 2013-10-30 |
| 48 | **Regression Testing** | baseline start none → 2013-06-11; baseline finish none → 2013-10-30 |
| 49 | Test Advisor Assignment | baseline start none → 2013-06-11; baseline finish none → 2013-06-24 |
| 50 | Test Instructor Assignment | baseline start none → 2013-08-28; baseline finish none → 2013-09-25 |
| 51 | Test Supervisor Assignment | baseline start none → 2013-09-26; baseline finish none → 2013-10-30 |
| 52 | Test Reg Control List | baseline start none → 2013-09-03; baseline finish none → 2013-09-04 |
| 53 | Regression testing complete | baseline start none → 2013-10-30; baseline finish none → 2013-10-30 |
| 69 | **PE REG Upgrade** | baseline start 2013-02-07 → 2013-01-14; baseline finish 2013-03-07 → 2013-12-16 |
| 90 | **Phase II - Full CSF Upgrade** | baseline start none → 2013-01-14; baseline finish none → 2013-12-16 |
| 91 | **Development** | baseline start none → 2013-08-21; baseline finish none → 2013-10-22 |
| 92 | Ramp up | baseline start none → 2013-08-21; baseline finish none → 2013-08-23 |
| 93 | Update applicationContext files and reorganize | baseline start none → 2013-08-26; baseline finish none → 2013-08-26 |
| 94 | Make changes to DAO modules (21 modules) | baseline start none → 2013-08-27; baseline finish none → 2013-09-12 |
| 95 | Fix service modules unit tests and create new unit tests for DAO | baseline start none → 2013-09-13; baseline finish none → 2013-10-08 |
| 96 | Replace sfbreCurrentPerson domain object and related objects and mappings | baseline start none → 2013-10-09; baseline finish none → 2013-10-15 |
| 97 | Rewrite the email codes to use the new csf email service | baseline start none → 2013-10-16; baseline finish none → 2013-10-22 |
| 98 | Development complete | baseline start none → 2013-10-22; baseline finish none → 2013-10-22 |
| 99 | **Testing** | baseline start none → 2013-10-23; baseline finish none → 2013-12-03 |
| 100 | Do test planning | baseline start none → 2013-10-23; baseline finish none → 2013-10-24 |
| 101 | Execute regression test | baseline start none → 2013-10-25; baseline finish none → 2013-11-27 |
| 102 | Perform user test | baseline start none → 2013-12-02; baseline finish none → 2013-12-02 |
| 103 | Perform load test | baseline start none → 2013-12-03; baseline finish none → 2013-12-03 |
| 104 | **Deployment Preparation** | baseline start none → 2013-12-02; baseline finish none → 2013-12-16 |
| 105 | Create deployment plan | baseline start none → 2013-12-02; baseline finish none → 2013-12-13 |
| 106 | Review deployment plan with participants | baseline start none → 2013-12-16; baseline finish none → 2013-12-16 |
| 107 | Go-live | baseline start none → 2013-01-14; baseline finish none → 2013-01-14 |
| 108 | PE REG upgrade complete | baseline start none → 2013-01-14; baseline finish none → 2013-01-14 |

## Version 35 (saved 2013-09-13)

Last finish stays 2013-12-16.

Changed:

| ID | Task | Start | Finish | Duration | Complete | Total float |
| --- | --- | --- | --- | --- | --- | --- |
| 31 | **Convert SAIS-Common Apps to CSF 2.0** |  |  |  | 42% → 48% |  |
| 40 | **Bundle 1 (Advisor Assignment, Instructor Assignment, Supervisor Assignment, and Reg Control List)** |  |  |  | 29% → 37% |  |
| 47 | **Testing** |  |  |  | 9% → 21% | 2d → 20d |
| 48 | **Regression Testing** |  |  |  | 18% → 40% | 13d → 19d |
| 50 | Test Instructor Assignment | 2013-08-28 A |  |  | 0% → 60% | 19d → 15d |
| 52 | Test Reg Control List | 2013-09-03 → 2013-09-11 A (+8d) | 2013-09-04 → 2013-09-20 (+16d) | 2d → 8d | 0% → 38% | 28d → 17d |
| 58 | Test Reg Control List | 2013-09-05 → 2013-09-23 (+18d) | 2013-10-02 → 2013-10-21 (+19d) |  |  | 29d → 17d |
| 66 | Deploy Reg Control List | 2013-10-03 → 2013-10-22 (+19d) | 2013-10-03 → 2013-10-22 (+19d) |  |  | 30d → 17d |

## Version 36 (saved 2013-09-17)

Last finish 2013-12-16 → 2014-01-13 (+28d).

Added:

| ID | Task | Duration | Start | Finish | Predecessors |
| --- | --- | --- | --- | --- | --- |
| 62 | **Instructor and Supervisor Assignment** | 2d? | 2013-11-15 | 2013-11-18 |  |
| 65 | Instructor and Superviosr Assignment deployment plan complete | 0d | 2013-11-18 | 2013-11-18 | 64 |
| 66 | **Reg Control List** | 2d? | 2013-01-14 | 2013-01-15 |  |
| 67 | Create deployment plan | 1d? | 2013-01-14 | 2013-01-14 |  |
| 68 | Review deployment plan with participants | 1d? | 2013-01-15 | 2013-01-15 | 67 |
| 69 | Instructor and Superviosr Assignment deployment plan complete | 0d | 2013-01-15 | 2013-01-15 | 68 |
| 70 | **Advisor Assignment** | 221d? | 2013-01-14 | 2013-11-18 |  |
| 71 | Create deployment plan | 1d? | 2013-01-14 | 2013-01-14 |  |
| 72 | Review deployment plan with participants | 1d? | 2013-01-15 | 2013-01-15 | 71 |
| 73 | Instructor and Superviosr Assignment deployment plan complete | 0d | 2013-01-15 | 2013-01-15 | 72 |
| 74 | Deployment planning complete | 0d | 2013-11-18 | 2013-11-18 | 65, 69, 73 |

Changed:

| ID | Task | Start | Finish | Duration | Total float | Predecessors | Other |
| --- | --- | --- | --- | --- | --- | --- | --- |
| 31 | **Convert SAIS-Common Apps to CSF 2.0** |  | 2013-11-18 → 2014-01-13 (+56d) | 221d? → 260.5d? | 20d → 0d |  |  |
| 40 | **Bundle 1 (Advisor Assignment, Instructor Assignment, Supervisor Assignment, and Reg Control List)** |  | 2013-11-18 → 2014-01-13 (+56d) | 221d? → 260.5d? | 20d → 0d |  |  |
| 61 | **Deployment Preparation** | 2013-11-15 → 2013-01-14 (-305d) |  | 2d? → 221d? | 20d → 39d |  |  |
| 75 | **Deployments** | 2013-01-14 → 2013-11-04 (+294d) | 2013-11-15 → 2014-01-13 (+59d) | 220d? → 50.5d | 1d → 0d |  |  |
| 76 | Deploy Instructor and Supervisor Assignment | 2013-11-15 → 2013-11-25 (+10d) | 2013-11-15 → 2013-11-25 (+10d) | 1d? → 0.5d | 1d → 35d | 56, 57 → 56, 57, 65 | constraint none → start no earlier than 2013-11-25 |
| 77 | Deploy Reg Control List | 2013-10-22 → 2013-11-04 (+13d) | 2013-10-22 → 2013-11-04 (+13d) | 1d? → 0.5d | 17d → 50d | 58 → 58, 69 | constraint none → start no earlier than 2013-11-04 |
| 78 | Deploy Advisor Assignment | 2013-09-24 → 2014-01-13 (+111d) | 2013-09-24 → 2014-01-13 (+111d) | 1d? → 0.5d | 38d → 0d | 55 → 55, 74 | constraint none → start no earlier than 2014-01-13 |
| 79 | Deployments complete | 2013-01-14 → 2014-01-13 (+364d) | 2013-01-14 → 2014-01-13 (+364d) | 1d? → 0d | 218d → 0d | none → 76, 77, 78 |  |

## Version 37 (saved 2013-09-19)

Last finish stays 2014-01-13.

Added:

| ID | Task | Duration | Start | Finish | Predecessors | Resources |
| --- | --- | --- | --- | --- | --- | --- |
| 80 | Bundle 1 complete | 0d | 2014-01-13 | 2014-01-13 | 79 | René [25%] |

Changed:

| ID | Task | Start | Finish | Duration | Complete | Total float | Predecessors | Other |
| --- | --- | --- | --- | --- | --- | --- | --- | --- |
| 31 | **Convert SAIS-Common Apps to CSF 2.0** | 2013-01-14 A → 2013-03-22 A (+67d) |  | 260.5d? → 211.5d | 48% → 43% |  |  |  |
| 40 | **Bundle 1 (Advisor Assignment, Instructor Assignment, Supervisor Assignment, and Reg Control List)** | 2013-01-14 A → 2013-05-28 A (+134d) |  | 260.5d? → 164.5d | 37% → 33% |  |  |  |
| 61 | **Deployment Preparation** | 2013-01-14 → 2013-10-21 (+280d) | 2013-11-18 → 2014-01-09 (+52d) | 221d? → 59d |  | 39d → 1d |  |  |
| 62 | **Instructor and Supervisor Assignment** | 2013-11-15 → 2013-11-12 (-3d) | 2013-11-18 → 2013-11-22 (+4d) | 2d? → 9d |  | 39d → 35d |  |  |
| 63 | Create deployment plan | 2013-11-15 → 2013-11-12 (-3d) | 2013-11-15 → 2013-11-21 (+6d) | 1d? → 8d |  | 39.5d → 35d | 54 → 57FS-4d | resources none → René [25%] |
| 64 | Review deployment plan with participants | 2013-11-18 → 2013-11-22 (+4d) | 2013-11-18 → 2013-11-22 (+4d) | 1d? → 1d |  | 39.5d → 35d |  | resources none → René [25%] |
| 65 | Instructor and Superviosr Assignment deployment plan complete | 2013-11-18 → 2013-11-22 (+4d) | 2013-11-18 → 2013-11-22 (+4d) |  |  | 39d → 35d |  | resources none → René [25%] |
| 66 | **Reg Control List** | 2013-01-14 → 2013-10-21 (+280d) | 2013-01-15 → 2013-10-31 (+289d) | 2d? → 9d |  | 258d → 51d |  |  |
| 67 | Create deployment plan | 2013-01-14 → 2013-10-21 (+280d) | 2013-01-14 → 2013-10-30 (+289d) | 1d? → 8d |  | 258d → 51d | none → 58FS-1d | resources none → René [25%] |
| 68 | Review deployment plan with participants | 2013-01-15 → 2013-10-31 (+289d) | 2013-01-15 → 2013-10-31 (+289d) | 1d? → 1d |  | 258d → 51d |  | resources none → René [25%] |
| 69 | Instructor and Superviosr Assignment deployment plan complete | 2013-01-15 → 2013-10-31 (+289d) | 2013-01-15 → 2013-10-31 (+289d) |  |  | 258d → 51d |  | resources none → René [25%] |
| 70 | **Advisor Assignment** | 2013-01-14 → 2013-12-30 (+350d) | 2013-11-18 → 2014-01-09 (+52d) | 221d? → 9d |  | 39d → 1d |  |  |
| 71 | Create deployment plan | 2013-01-14 → 2013-12-30 (+350d) | 2013-01-14 → 2014-01-08 (+359d) | 1d? → 8d |  | 258d → 1d | none → 55FS+69d | resources none → René [25%] |
| 72 | Review deployment plan with participants | 2013-01-15 → 2014-01-09 (+359d) | 2013-01-15 → 2014-01-09 (+359d) | 1d? → 1d |  | 258d → 1d |  | resources none → René [25%] |
| 73 | Instructor and Superviosr Assignment deployment plan complete | 2013-01-15 → 2014-01-09 (+359d) | 2013-01-15 → 2014-01-09 (+359d) |  |  | 258d → 1d |  | resources none → René [25%] |
| 74 | Deployment planning complete | 2013-11-18 → 2014-01-09 (+52d) | 2013-11-18 → 2014-01-09 (+52d) |  |  | 39d → 1d |  | resources none → René [25%] |
| 76 | Deploy Instructor and Supervisor Assignment |  |  |  |  |  |  | resources none → René [25%] |
| 77 | Deploy Reg Control List |  |  |  |  |  |  | resources none → René [25%] |
| 78 | Deploy Advisor Assignment |  |  |  |  |  |  | resources none → René [25%] |
| 79 | Deployments complete |  |  |  |  |  |  | resources none → René [25%] |

## Version 38 (saved 2013-09-26)

Last finish stays 2014-01-13. Complete tasks 77 → 78.

Changed:

| ID | Task | Start | Finish | Duration | Complete | Total float | Predecessors | Other |
| --- | --- | --- | --- | --- | --- | --- | --- | --- |
| 31 | **Convert SAIS-Common Apps to CSF 2.0** |  |  |  | 43% → 50% |  |  | baseline finish 2013-10-30 → 2014-01-13 |
| 40 | **Bundle 1 (Advisor Assignment, Instructor Assignment, Supervisor Assignment, and Reg Control List)** |  |  |  | 33% → 41% |  |  | baseline finish 2013-10-30 → 2014-01-13 |
| 47 | **Testing** |  | 2013-11-14 → 2013-11-18 (+4d) | 113d → 115d | 21% → 32% | 41.5d → 39.5d |  |  |
| 48 | **Regression Testing** |  | 2013-10-30 → 2013-11-01 (+2d) | 102d → 104d | 40% → 31% | 52.5d → 50.5d |  |  |
| 49 | Test Advisor Assignment |  |  |  |  |  |  | resources Jack [50%] → Jack |
| 50 | Test Instructor Assignment |  | 2013-09-25 → 2013-09-26 (+1d) | 20d → 21d | 60% → 57% | 35d → 28d |  |  |
| 51 | Test Supervisor Assignment | 2013-09-26 → 2013-09-30 (+4d) | 2013-10-30 → 2013-11-01 (+2d) |  |  | 38d → 28d | 50, 43 → 50FS+1d, 43 |  |
| 52 | Test Reg Control List | 2013-09-11 A → 2013-09-03 (-8d) | 2013-09-20 → 2013-09-24 (+4d) | 8d → 16d | 38% → 0% | 51d → 40d |  |  |
| 53 | Regression testing complete | 2013-10-30 → 2013-11-01 (+2d) | 2013-10-30 → 2013-11-01 (+2d) |  |  | 52.5d → 50.5d |  |  |
| 54 | **User Testing** | 2013-08-27 A | 2013-11-14 → 2013-11-18 (+4d) | 58d → 60d | 0% → 32% | 1d → 39.5d |  |  |
| 55 | Test Advisor Assignment | 2013-08-27 A | 2013-09-23 A |  | 0% → 100% | 1d → none |  |  |
| 56 | Test Instructor Assignment | 2013-09-26 → 2013-09-30 (+4d) | 2013-10-09 → 2013-10-11 (+2d) |  |  | 54d → 45d | 50, 55 → 50FS+1d, 55 |  |
| 57 | Test Supervisor Assignment | 2013-10-31 → 2013-11-04 (+4d) | 2013-11-14 → 2013-11-18 (+4d) |  |  | 39d → 30d |  |  |
| 58 | Test Reg Control List | 2013-09-23 → 2013-09-30 (+7d) | 2013-10-21 → 2013-10-28 (+7d) |  |  | 57d → 41d | 52 → 52FS+3d |  |
| 59 | User Testing Complete | 2013-11-14 → 2013-11-18 (+4d) | 2013-11-14 → 2013-11-18 (+4d) |  |  | 41.5d → 39.5d |  |  |
| 60 | Testing complete | 2013-11-14 → 2013-11-18 (+4d) | 2013-11-14 → 2013-11-18 (+4d) |  |  | 41.5d → 39.5d |  |  |
| 61 | **Deployment Preparation** | 2013-10-21 → 2013-10-28 (+7d) | 2014-01-09 → 2014-01-10 (+1d) | 59d → 55d |  | 1d → 0.5d |  |  |
| 62 | **Instructor and Supervisor Assignment** | 2013-11-12 → 2013-11-13 (+1d) |  | 9d → 8d |  | 35d → 33d |  |  |
| 63 | Create deployment plan | 2013-11-12 → 2013-11-13 (+1d) |  | 8d → 7d |  | 35d → 33d |  |  |
| 66 | **Reg Control List** | 2013-10-21 → 2013-10-28 (+7d) | 2013-10-31 → 2013-11-01 (+1d) | 9d → 5d |  | 51d → 50d |  |  |
| 67 | Create deployment plan | 2013-10-21 → 2013-10-28 (+7d) | 2013-10-30 → 2013-10-31 (+1d) | 8d → 4d |  | 51d → 50d |  |  |
| 68 | Review deployment plan with participants | 2013-10-31 → 2013-11-01 (+1d) | 2013-10-31 → 2013-11-01 (+1d) |  |  | 51d → 50d |  |  |
| 69 | Instructor and Superviosr Assignment deployment plan complete | 2013-10-31 → 2013-11-01 (+1d) | 2013-10-31 → 2013-11-01 (+1d) |  |  | 51d → 50d |  |  |
| 70 | **Advisor Assignment** |  | 2014-01-09 → 2014-01-10 (+1d) | 9d → 10d |  | 1d → 0.5d |  |  |
| 71 | Create deployment plan |  | 2014-01-08 → 2014-01-09 (+1d) | 8d → 7d |  | 1d → 0.5d |  |  |
| 72 | Review deployment plan with participants | 2014-01-09 → 2014-01-10 (+1d) | 2014-01-09 → 2014-01-10 (+1d) |  |  | 1d → 0.5d |  |  |
| 73 | Instructor and Superviosr Assignment deployment plan complete | 2014-01-09 → 2014-01-10 (+1d) | 2014-01-09 → 2014-01-10 (+1d) |  |  | 1d → 0.5d |  |  |
| 74 | Deployment planning complete | 2014-01-09 → 2014-01-10 (+1d) | 2014-01-09 → 2014-01-10 (+1d) |  |  | 1d → 0.5d |  |  |
| 75 | **Deployments** |  |  |  |  |  |  | baseline start none → 2013-11-04; baseline finish none → 2014-01-13 |
| 76 | Deploy Instructor and Supervisor Assignment |  |  |  |  |  |  | baseline start none → 2013-11-25; baseline finish none → 2013-11-25 |
| 77 | Deploy Reg Control List |  |  |  |  |  |  | baseline start none → 2013-11-04; baseline finish none → 2013-11-04 |
| 78 | Deploy Advisor Assignment |  |  |  |  |  | 55, 74 → 55, 71 | baseline start none → 2014-01-13; baseline finish none → 2014-01-13 |
| 79 | Deployments complete |  |  |  |  |  |  | baseline start none → 2014-01-13; baseline finish none → 2014-01-13 |
| 80 | Bundle 1 complete |  |  |  |  |  |  | baseline start none → 2014-01-13; baseline finish none → 2014-01-13 |

## Version 39 (saved 2013-10-02)

Last finish stays 2014-01-13. Complete tasks 78 → 79.

Changed:

| ID | Task | Start | Finish | Complete | Total float |
| --- | --- | --- | --- | --- | --- |
| 31 | **Convert SAIS-Common Apps to CSF 2.0** |  |  | 50% → 57% |  |
| 40 | **Bundle 1 (Advisor Assignment, Instructor Assignment, Supervisor Assignment, and Reg Control List)** |  |  | 41% → 49% |  |
| 47 | **Testing** |  |  | 32% → 43% |  |
| 48 | **Regression Testing** |  |  | 31% → 48% |  |
| 50 | Test Instructor Assignment |  | 2013-09-26 A | 57% → 100% | 28d → none |
| 51 | Test Supervisor Assignment | 2013-09-30 A |  | 0% → 13% | 28d → 30d |
| 54 | **User Testing** |  |  | 32% → 37% |  |
| 56 | Test Instructor Assignment | 2013-09-30 A |  | 0% → 30% |  |

## Version 40 (saved 2013-10-09)

Last finish stays 2014-01-13.

Changed:

| ID | Task | Start | Complete | Total float |
| --- | --- | --- | --- | --- |
| 31 | **Convert SAIS-Common Apps to CSF 2.0** |  | 57% → 65% |  |
| 40 | **Bundle 1 (Advisor Assignment, Instructor Assignment, Supervisor Assignment, and Reg Control List)** |  | 49% → 58% |  |
| 47 | **Testing** |  | 43% → 57% |  |
| 48 | **Regression Testing** |  | 48% → 55% |  |
| 51 | Test Supervisor Assignment |  | 13% → 33% |  |
| 54 | **User Testing** |  | 37% → 59% |  |
| 56 | Test Instructor Assignment |  | 30% → 80% |  |
| 58 | Test Reg Control List | 2013-09-30 A | 0% → 40% | 41d → 50d |

## Version 41 (saved 2013-10-16)

Last finish stays 2014-01-13. Complete tasks 79 → 81.

Changed:

| ID | Task | Start | Finish | Complete | Total float |
| --- | --- | --- | --- | --- | --- |
| 31 | **Convert SAIS-Common Apps to CSF 2.0** |  |  | 65% → 77% |  |
| 40 | **Bundle 1 (Advisor Assignment, Instructor Assignment, Supervisor Assignment, and Reg Control List)** |  |  | 58% → 73% |  |
| 47 | **Testing** |  |  | 57% → 78% |  |
| 48 | **Regression Testing** |  |  | 55% → 92% |  |
| 51 | Test Supervisor Assignment |  |  | 33% → 75% |  |
| 52 | Test Reg Control List | 2013-09-03 A | 2013-09-24 A | 0% → 100% | 40d → none |
| 54 | **User Testing** |  |  | 59% → 63% |  |
| 56 | Test Instructor Assignment |  | 2013-10-11 A | 80% → 100% | 45d → none |

## Version 42 (saved 2013-11-04)

Last finish stays 2014-01-13. Complete tasks 81 → 88.

Changed:

| ID | Task | Start | Finish | Duration | Complete | Total float | Predecessors |
| --- | --- | --- | --- | --- | --- | --- | --- |
| 31 | **Convert SAIS-Common Apps to CSF 2.0** |  |  |  | 77% → 90% |  |  |
| 40 | **Bundle 1 (Advisor Assignment, Instructor Assignment, Supervisor Assignment, and Reg Control List)** |  |  |  | 73% → 89% |  |  |
| 47 | **Testing** |  | 2013-11-18 → 2013-11-08 (-10d) | 115d → 109d | 78% → 97% | 39.5d → 45.5d |  |
| 48 | **Regression Testing** |  | 2013-11-01 → 2013-10-25 A (-7d) | 104d → 99d | 92% → 100% | 50.5d → none |  |
| 51 | Test Supervisor Assignment |  | 2013-11-01 → 2013-10-25 A (-7d) | 24d → 19d | 75% → 100% | 30d → none |  |
| 53 | Regression testing complete | 2013-11-01 → 2013-10-25 A (-7d) | 2013-11-01 → 2013-10-25 A (-7d) |  | 0% → 100% | 50.5d → none |  |
| 54 | **User Testing** |  | 2013-11-18 → 2013-11-08 (-10d) | 60d → 54d | 63% → 94% | 39.5d → 45.5d |  |
| 57 | Test Supervisor Assignment | 2013-11-04 → 2013-10-28 A (-7d) | 2013-11-18 → 2013-11-08 (-10d) |  | 0% → 60% | 30d → 37d |  |
| 58 | Test Reg Control List |  | 2013-10-28 → 2013-10-31 A (+3d) | 20d → 23d | 40% → 100% | 50d → none |  |
| 59 | User Testing Complete | 2013-11-18 → 2013-11-08 (-10d) | 2013-11-18 → 2013-11-08 (-10d) |  |  | 39.5d → 45.5d |  |
| 60 | Testing complete | 2013-11-18 → 2013-11-08 (-10d) | 2013-11-18 → 2013-11-08 (-10d) |  |  | 39.5d → 45.5d |  |
| 61 | **Deployment Preparation** | 2013-10-28 → 2013-10-21 A (-7d) |  | 55d → 60d | 0% → 24% |  |  |
| 62 | **Instructor and Supervisor Assignment** | 2013-11-13 → 2013-11-05 (-8d) | 2013-11-22 → 2013-11-15 (-7d) | 8d → 9d |  | 33d → 39d |  |
| 63 | Create deployment plan | 2013-11-13 → 2013-11-05 (-8d) | 2013-11-21 → 2013-11-14 (-7d) |  |  | 33d → 39d |  |
| 64 | Review deployment plan with participants | 2013-11-22 → 2013-11-15 (-7d) | 2013-11-22 → 2013-11-15 (-7d) |  |  | 35d → 40d |  |
| 65 | Instructor and Superviosr Assignment deployment plan complete | 2013-11-22 → 2013-11-15 (-7d) | 2013-11-22 → 2013-11-15 (-7d) |  |  | 35d → 40d |  |
| 66 | **Reg Control List** | 2013-10-28 → 2013-10-21 A (-7d) | 2013-11-01 → 2013-10-29 A (-3d) | 5d → 7d | 0% → 100% | 50d → none |  |
| 67 | Create deployment plan | 2013-10-28 → 2013-10-21 A (-7d) | 2013-10-31 → 2013-10-24 A (-7d) |  | 0% → 100% | 50d → none |  |
| 68 | Review deployment plan with participants | 2013-11-01 → 2013-10-29 A (-3d) | 2013-11-01 → 2013-10-29 A (-3d) |  | 0% → 100% | 50d → none | 67 → 67FS+2d |
| 69 | Instructor and Superviosr Assignment deployment plan complete | 2013-11-01 → 2013-10-29 A (-3d) | 2013-11-01 → 2013-10-29 A (-3d) |  | 0% → 100% | 50d → none |  |
| 75 | **Deployments** | 2013-11-04 A |  |  | 0% → 33% |  |  |
| 77 | Deploy Reg Control List | 2013-11-04 A | 2013-11-04 A |  | 0% → 100% | 50d → none |  |

## Version 43 (saved 2013-11-08)

Last finish stays 2014-01-13. Complete tasks 88 → 92.

Changed:

| ID | Task | Start | Finish | Duration | Complete | Total float | Predecessors |
| --- | --- | --- | --- | --- | --- | --- | --- |
| 31 | **Convert SAIS-Common Apps to CSF 2.0** |  |  |  | 90% → 95% |  |  |
| 40 | **Bundle 1 (Advisor Assignment, Instructor Assignment, Supervisor Assignment, and Reg Control List)** |  |  |  | 89% → 94% |  |  |
| 47 | **Testing** |  | 2013-11-08 A |  | 97% → 100% | 45.5d → none |  |
| 54 | **User Testing** |  | 2013-11-08 A |  | 94% → 100% | 45.5d → none |  |
| 57 | Test Supervisor Assignment |  | 2013-11-08 A |  | 60% → 100% | 37d → none |  |
| 59 | User Testing Complete | 2013-11-08 A | 2013-11-08 A |  | 0% → 100% | 45.5d → none |  |
| 60 | Testing complete | 2013-11-08 A | 2013-11-08 A |  | 0% → 100% | 45.5d → none |  |
| 61 | **Deployment Preparation** |  |  |  | 24% → 40% |  |  |
| 62 | **Instructor and Supervisor Assignment** | 2013-11-05 → 2013-11-07 A (+2d) | 2013-11-15 → 2013-11-13 (-2d) | 9d → 5d | 0% → 50% | 39d → 42d |  |
| 63 | Create deployment plan | 2013-11-05 → 2013-11-07 A (+2d) | 2013-11-14 → 2013-11-07 A (-7d) | 7d → 1d | 0% → 100% | 39d → none |  |
| 64 | Review deployment plan with participants | 2013-11-15 → 2013-11-13 (-2d) | 2013-11-15 → 2013-11-13 (-2d) |  |  | 40d → 42d | 63 → 63FS+3d |
| 65 | Instructor and Superviosr Assignment deployment plan complete | 2013-11-15 → 2013-11-13 (-2d) | 2013-11-15 → 2013-11-13 (-2d) |  |  | 40d → 42d |  |

## Version 44 (saved 2013-11-13)

Last finish stays 2014-01-13. Complete tasks 92 → 94.

Changed:

| ID | Task | Start | Finish | Complete | Total float |
| --- | --- | --- | --- | --- | --- |
| 31 | **Convert SAIS-Common Apps to CSF 2.0** |  |  | 95% → 96% |  |
| 40 | **Bundle 1 (Advisor Assignment, Instructor Assignment, Supervisor Assignment, and Reg Control List)** |  |  | 94% → 95% |  |
| 61 | **Deployment Preparation** |  |  | 40% → 47% |  |
| 62 | **Instructor and Supervisor Assignment** |  | 2013-11-13 A | 50% → 100% | 42d → none |
| 64 | Review deployment plan with participants | 2013-11-13 A | 2013-11-13 A | 0% → 100% | 42d → none |
| 65 | Instructor and Superviosr Assignment deployment plan complete | 2013-11-13 A | 2013-11-13 A | 0% → 100% | 42d → none |

## Version 45 (saved 2013-11-21)

Last finish 2014-01-13 → 2013-12-18 (-26d).

Changed:

| ID | Task | Start | Finish | Duration | Total float | Predecessors | Other |
| --- | --- | --- | --- | --- | --- | --- | --- |
| 31 | **Convert SAIS-Common Apps to CSF 2.0** |  | 2014-01-13 → 2013-12-18 (-26d) | 211.5d → 193.5d |  |  |  |
| 40 | **Bundle 1 (Advisor Assignment, Instructor Assignment, Supervisor Assignment, and Reg Control List)** |  | 2014-01-13 → 2013-12-18 (-26d) | 164.5d → 146.5d |  |  |  |
| 61 | **Deployment Preparation** |  | 2014-01-10 → 2013-12-09 (-32d) | 60d → 35.5d | 0.5d → 7d |  |  |
| 70 | **Advisor Assignment** | 2013-12-30 → 2013-11-25 (-35d) | 2014-01-10 → 2013-12-09 (-32d) |  | 0.5d → 7d |  |  |
| 71 | Create deployment plan | 2013-12-30 → 2013-11-25 (-35d) | 2014-01-09 → 2013-12-06 (-34d) |  | 0.5d → 7d | 55FS+69d → 76 |  |
| 72 | Review deployment plan with participants | 2014-01-10 → 2013-12-06 (-35d) | 2014-01-10 → 2013-12-09 (-32d) |  | 0.5d → 7d |  |  |
| 73 | Advisor Assignment deployment plan complete | 2014-01-10 → 2013-12-09 (-32d) | 2014-01-10 → 2013-12-09 (-32d) |  | 0.5d → 7d |  | was named Instructor and Superviosr Assignment deployment plan complete |
| 74 | Deployment planning complete | 2014-01-10 → 2013-12-09 (-32d) | 2014-01-10 → 2013-12-09 (-32d) |  | 0.5d → 7d |  |  |
| 75 | **Deployments** |  | 2014-01-13 → 2013-12-18 (-26d) | 50.5d → 32.5d |  |  |  |
| 78 | Deploy Advisor Assignment | 2014-01-13 → 2013-12-18 (-26d) | 2014-01-13 → 2013-12-18 (-26d) |  |  |  | constraint start no earlier than 2014-01-13 → start no earlier than 2013-12-18 |
| 79 | Deployments complete | 2014-01-13 → 2013-12-18 (-26d) | 2014-01-13 → 2013-12-18 (-26d) |  |  |  |  |
| 80 | Bundle 1 complete | 2014-01-13 → 2013-12-18 (-26d) | 2014-01-13 → 2013-12-18 (-26d) |  |  |  |  |

## Version 46 (saved 2013-12-18)

Last finish 2013-12-18 → 2013-12-16 (-2d). Complete tasks 94 → 102.

Changed:

| ID | Task | Start | Finish | Duration | Complete | Total float |
| --- | --- | --- | --- | --- | --- | --- |
| 31 | **Convert SAIS-Common Apps to CSF 2.0** |  | 2013-12-18 → 2013-12-12 A (-6d) | 193.5d → 190d | 96% → 100% | 0d → none |
| 40 | **Bundle 1 (Advisor Assignment, Instructor Assignment, Supervisor Assignment, and Reg Control List)** |  | 2013-12-18 → 2013-12-12 A (-6d) | 146.5d → 143d | 95% → 100% | 0d → none |
| 61 | **Deployment Preparation** |  | 2013-12-09 A |  | 47% → 100% | 7d → none |
| 70 | **Advisor Assignment** | 2013-11-25 A | 2013-12-09 A |  | 0% → 100% | 7d → none |
| 71 | Create deployment plan | 2013-11-25 A | 2013-12-06 A |  | 0% → 100% | 7d → none |
| 72 | Review deployment plan with participants | 2013-12-06 A | 2013-12-09 A |  | 0% → 100% | 7d → none |
| 73 | Advisor Assignment deployment plan complete | 2013-12-09 A | 2013-12-09 A |  | 0% → 100% | 7d → none |
| 74 | Deployment planning complete | 2013-12-09 A | 2013-12-09 A |  | 0% → 100% | 7d → none |
| 75 | **Deployments** |  | 2013-12-18 → 2013-12-12 A (-6d) | 32.5d → 29d | 33% → 100% | 0d → none |
| 76 | Deploy Instructor and Supervisor Assignment | 2013-11-25 A | 2013-11-25 A |  | 0% → 100% | 9d → none |
| 78 | Deploy Advisor Assignment | 2013-12-18 → 2013-12-12 A (-6d) | 2013-12-18 → 2013-12-12 A (-6d) | 0.5d → 0d | 0% → 100% | 0d → none |
| 79 | Deployments complete | 2013-12-18 → 2013-12-12 A (-6d) | 2013-12-18 → 2013-12-12 A (-6d) |  | 0% → 100% | 0d → none |
| 80 | Bundle 1 complete | 2013-12-18 → 2013-12-12 A (-6d) | 2013-12-18 → 2013-12-12 A (-6d) |  | 0% → 100% | 0d → none |
